# BP Av ESPERANZA Av 68

Schedule from MS Project, 2026-03-02 to 2026-07-29.

## Calendars

- BP BOGOTA: Mon-Sat 08:00-12:00, 13:00-17:00; Sun off.

## Schedule

| ID | WBS | Task | Type | Duration | Start | Finish | Predecessors | Total slack | Free slack |
| --- | --- | --- | --- | --- | --- | --- | --- | --- | --- |
| 1 | 1 | INCIO | milestone | 0d | 2026-03-02 | 2026-03-02 |  | 5d | 0d |
| 2 | 2 | **ACTIVIDADES DE GESTION AMERICAS CON 26** |  | 30d | 2026-03-02 | 2026-04-04 |  |  |  |
| 3 | 2.1 | TRAMITE ADMISTRATIVO |  | 10d | 2026-03-02 | 2026-03-12 |  | 5d | 0d |
| 4 | 2.2 | TRAMITE LEGAL |  | 10d | 2026-03-13 | 2026-03-24 | 3 | 5d | 0d |
| 5 | 2.3 | AUTORIZACION AUTOMATICA |  | 5d | 2026-03-13 | 2026-03-18 | 3 | 15d |  |
| 6 | 2.4 | AUTORIZACION LEGAL |  | 5d | 2026-03-25 | 2026-03-30 | 4 | 5d |  |
| 7 | 3 | **URBANISMO** |  | 44d | 2026-04-04 | 2026-05-26 | 2 | 0d |  |
| 8 | 3.1 | PRELIMINARES | milestone | 0d | 2026-04-04 | 2026-04-04 |  | 44d |  |
| 9 | 3.2 | LOCALIZACIÓN Y REPLANTEO OBRA ARQUITECTÓNICA |  | 3d | 2026-04-06 | 2026-04-08 | 4 | 0d |  |
| 10 | 3.3 | CERRAMIENTO EN VARA ROLLIZA Y LONA H=1.50 M . DISTANCIA ENTRE POSTES 2 M |  | 15d | 2026-04-09 | 2026-04-25 | 9 | 0d |  |
| 11 | 3.4 | DEMOLICIÓN DE ANDÉN E > A 12 CM. (INCLUYE RETIRO Y ACARREO LIBRE HASTA 5 KM.) |  | 8d | 2026-04-27 | 2026-05-05 | 10 | 0d |  |
| 12 | 3.5 | RELLENO EN RECEBO COMPACTADO B200 |  | 6d | 2026-05-20 | 2026-05-26 | 13 | 0d |  |
| 13 | 3.6 | EXCAVACIÓN MANUAL EN MATERIAL COMÚN |  | 12d | 2026-05-06 | 2026-05-19 | 11 | 0d |  |
| 14 | 3.7 | ESPACIOS DEPORTIVOS | milestone | 0d | 2026-04-04 | 2026-04-04 |  | 44d |  |
| 15 | 3.8 | SUMINISTRO, TRANSPORTE E INSTALACIÓN DE PARQUE INFANTIL ESTÁNDAR (COLUMPIOS, RODADERO, PISO EN GOMA, CERRAMIENTO EN MALLA CON ESTRUCTURA, INCLUYE ANCLAJES Y ASEO FINAL) |  | 25d | 2026-04-09 | 2026-05-07 | 9 | 16d |  |
| 16 | 3.9 | ELEMENTOS URBANOS | milestone | 0d | 2026-04-04 | 2026-04-04 |  | 44d |  |
| 17 | 3.10 | SUMINISTRO E INSTALACIÓN DE CAMARAS DE CIBERSEGURIDAD CIRCUITO CERRADO INCLUIDO CONECTIVIDAD WIFI |  | 10d | 2026-04-09 | 2026-04-20 | 9 | 31d |  |
| 18 | 3.11 | MATERAS EN LADRILLO COMÚN (CON INPERMEABILIZACIÓN, H=60 CM) PASTO NATURAL |  | 15d | 2026-05-02 | 2026-05-19 | 20 | 6d |  |
| 19 | 3.12 | PISOS Y ACABADOS ARQUITECTONICOS | milestone | 0d | 2026-04-08 | 2026-04-08 | 9 | 41d |  |
| 20 | 3.13 | SUMINISTRO E INSTALACIÓN DE ADOQUÍN PARA EXTERIORES FORMATO 15X18, COLOR TERRACOTA. |  | 20d | 2026-04-09 | 2026-05-01 | 9 | 6d | 0d |
| 21 | 3.14 | INSTALACIONES ELECTRICAS Y DE DATOS | milestone | 0d | 2026-04-04 | 2026-04-04 |  | 44d |  |
| 22 | 3.15 | SUMINISTRO E INSTALACIÓN DE ELEMENTOS DE ACOMETIDA AÉREA. CONEXIÓN DESDE RED TRENZADA DE B.T., BAJANTE HACIA EQUIPO DE MEDIDA EN TUBO IMC DE 1". 15 MTS |  | 4d | 2026-05-02 | 2026-05-06 | 20 | 7d | 0d |
| 23 | 3.16 | SUMINISTRO, INSTALACIÓN Y CONEXIONADO DE CABLE CONCENTRICO (ANTIFRAUDE) No. 2 x 6 +6 AWG EN COBRE PARA ACOMETIDA BIFÁSICA |  | 6d | 2026-05-07 | 2026-05-13 | 22 | 7d | 0d |
| 24 | 3.17 | SUMINISTRO E INSTALACION DE PUNTO DE INTERNET NO INCLUYE CABLE |  | 4d | 2026-05-14 | 2026-05-18 | 23 | 7d |  |
| 25 | 3.18 | INSTALACIONES HIDROSANITARIAS Y GAS | milestone | 0d | 2026-04-04 | 2026-04-04 |  | 44d |  |
| 26 | 3.19 | PAGO ACOMETIDA DE ACUEDUCTO Y ALCANTARILLADO |  | 3d | 2026-04-09 | 2026-04-11 | 9 | 16d | 0d |
| 27 | 3.20 | SUMINISTRO E INSTALACION TUBERÍA HIDRÁULICA HIDRAULICO 1/2" DE DISTRIBUCIÓN |  | 6d | 2026-04-24 | 2026-04-30 | 29 | 22d |  |
| 28 | 3.21 | SUMINISTRO E INSTALACION TUBERÍA SANITARIA DE RECOLECCIÓN 6* |  | 6d | 2026-04-24 | 2026-04-30 | 29 | 22d |  |
| 29 | 3.22 | EXCAVACIÓN MANUAL EN MATERIAL COMÚN |  | 10d | 2026-04-13 | 2026-04-23 | 26 | 16d | 0d |
| 30 | 3.23 | RELLENO EN RECEBO COMPACTADO B200 |  | 4d | 2026-04-24 | 2026-04-28 | 29 | 24d |  |
| 31 | 3.24 | SUMINISTRO E INSTALACIÓN DE CUARTO PARA GAS |  | 8d | 2026-04-24 | 2026-05-02 | 29 | 16d | 0d |
| 32 | 3.25 | ASEO Y RETIRO DE ESCOMBROS | milestone | 0d | 2026-04-04 | 2026-04-04 |  | 44d |  |
| 33 | 3.26 | RETIRO DE ESCOMBROS |  | 2d | 2026-05-04 | 2026-05-05 | 31 | 16d | 0d |
| 34 | 3.27 | ASEO FINAL |  | 2d | 2026-05-06 | 2026-05-07 | 33 | 16d |  |

| ID | WBS | Task | Type | Duration | Start | Finish | Predecessors | Total slack | Free slack | Constraint |
| --- | --- | --- | --- | --- | --- | --- | --- | --- | --- | --- |
| 35 | 4 | **MODULO TIENDAS** |  | 65d | 2026-05-15 | 2026-07-29 | 7FS-10d | 0d |  |  |
| 36 | 4.1 | PRELIMINARES | milestone | 0d | 2026-05-15 | 2026-05-15 |  | 65d |  |  |
| 37 | 4.2 | LOCALIZACIÓN Y REPLANTEO |  | 2d | 2026-05-15 | 2026-05-16 |  | 0d |  |  |
| 38 | 4.3 | DEMOLICIÓN DE ANDÉN E > A 12 CM. (INCLUYE RETIRO Y ACARREO LIBRE HASTA 5 KM.) |  | 4d | 2026-05-18 | 2026-05-21 | 37 | 0d |  |  |
| 39 | 4.4 | EXCAVACIÓN MANUAL EN MATERIAL COMÚN |  | 8d | 2026-05-22 | 2026-05-30 | 38 | 0d |  |  |
| 40 | 4.5 | ESTRUCTURA EN CONCRETO | milestone | 0d | 2026-05-15 | 2026-05-15 |  | 65d |  |  |
| 41 | 4.6 | SUMINISTRO E INSTALACION DE DADOS EN CONCRETO SIMPLE DE 4000 PSIDE 30X30 CMS |  | 8d | 2026-06-01 | 2026-06-09 | 39 | 0d |  |  |
| 42 | 4.7 | CONCRETO SIMPLE DE 28 Mpa. (4000 PSI) |  | 8d | 2026-06-10 | 2026-06-18 | 41 | 29d | 0d |  |
| 43 | 4.8 | RELLENO EN RECEBO COMPACTADO B200 |  | 6d | 2026-06-19 | 2026-06-25 | 42 | 29d |  |  |
| 44 | 4.9 | ESTRUCTURA METALICA | milestone | 0d | 2026-05-15 | 2026-05-15 |  | 65d |  |  |
| 45 | 4.10 | SUMINISTRO, TRANSPORTE, FABRICACIÓN, FIGURADA Y/O ROLADO, ENSAMBLAJE Y MONTAJE MANUAL DE ESTRUCTURA METALICA |  | 25d | 2026-06-10 | 2026-07-08 | 41 | 0d |  |  |
| 46 | 4.11 | SUMINISTRO E INSTALACIÓN DE ESMALTE SINTÉTICO PARA ESTRUCTURA METALICA. (INCLUYE BASE EN ANTICORROSIVO). |  | 10d | 2026-07-09 | 2026-07-20 | 45 | 8d |  |  |
| 47 | 4.12 | SUMINISTRO E INSTALACION CUBIERTA EN PERFILERIA METALICA, TEJA UPVC COLOR SEGÚN DISEÑO ESPESOR 6 MM. |  | 10d | 2026-07-09 | 2026-07-20 | 45 | 0d |  |  |
| 48 | 4.13 | SUMINISTRO E INSTALACION DE CANAL EN LAMINA COLD ROLLED CAL. 20 D=0.75 CON PINTURA Y ANTICORROSIVO |  | 8d | 2026-07-21 | 2026-07-29 | 47 | 0d |  | start no earlier than 2026-03-02 |
| 49 | 4.14 | SUMINISTRO E INSTALACION LAMINA EN SUPERBOARD DE 10 MM |  | 10d | 2026-07-09 | 2026-07-20 | 45 | 8d |  |  |
| 50 | 4.15 | Suministro e instalación de lámina microperforada en acero galvanizado |  | 4d | 2026-07-09 | 2026-07-13 | 45 | 8d | 0d |  |
| 51 | 4.16 | SUMINISTRO E INSTALACIÓN DE MESÓN 60 CM ANCHO EN LÁMINA GALVANIZADA CALIBRE 22 CON SOPORTES Y ANGULOS A=45 CM, PINTURA ELECTROSTÁTICA |  | 4d | 2026-07-14 | 2026-07-17 | 50 | 8d | 0d |  |
| 52 | 4.17 | POCETA EN LADRILLO Y ENCHAPE DE 0.6 m * 0.4 m |  | 2d | 2026-07-18 | 2026-07-20 | 51 | 8d |  |  |
| 53 | 4.18 | INSTALACIONES ELECTRICAS | milestone | 0d | 2026-07-08 | 2026-07-08 | 45 | 18d |  |  |
| 54 | 4.19 | SUMINISTRO E INSTALACION SALIDA DE ILUMINACION |  | 4d | 2026-07-09 | 2026-07-13 | 45 | 8d | 0d |  |
| 55 | 4.20 | SUMINISTRO E INSTALACION PUNTO ELECTRICO INTERRUPTOR |  | 4d | 2026-07-14 | 2026-07-17 | 54 | 10d |  |  |
| 56 | 4.21 | SUMINISTRO E INSTALACION TOMA DOBLE INCLUYE APARATO |  | 4d | 2026-07-14 | 2026-07-17 | 54 | 10d |  |  |
| 57 | 4.22 | SUMINISTRO E INSTALACION LUMINARIA LINEAL LED COMERCIAL 40 W LUZ DIA |  | 6d | 2026-07-14 | 2026-07-20 | 54 | 8d |  |  |
| 58 | 4.23 | INSTALACIONES HIDROSANITARIAS E HIDRAULICAS | milestone | 0d | 2026-05-15 | 2026-05-15 |  | 65d |  |  |
| 59 | 4.24 | SUMINISTRO E INSTALACION LAVAPLATOS SENCILLO EN ACERO INOXIDABLE |  | 6d | 2026-07-09 | 2026-07-15 | 45 | 6d | 0d |  |
| 60 | 4.25 | SUMINISTRO E INSTALACION PUNTO HIDRAULICO 1/2" |  | 6d | 2026-07-16 | 2026-07-22 | 59 | 6d |  |  |
| 61 | 4.26 | ASEO Y RETIRO DE ESCOMBROS | milestone | 0d | 2026-05-15 | 2026-05-15 |  | 65d |  |  |
| 62 | 4.27 | RETIRO DE ESCOMBROS |  | 2d | 2026-07-16 | 2026-07-17 | 59 | 8d | 0d |  |
| 63 | 4.28 | ASEO FINAL |  | 2d | 2026-07-18 | 2026-07-20 | 62 | 8d |  |  |

| ID | WBS | Task | Type | Duration | Start | Finish | Predecessors | Total slack | Free slack |
| --- | --- | --- | --- | --- | --- | --- | --- | --- | --- |
| 64 | 5 | **MODULO BAÑOS** |  | 46d | 2026-05-15 | 2026-07-07 | 7FS-10d | 19d |  |
| 65 | 5.1 | PRELIMINARES | milestone | 0d | 2026-05-15 | 2026-05-15 |  | 65d |  |
| 66 | 5.2 | LOCALIZACIÓN Y REPLANTEO |  | 1d | 2026-05-15 | 2026-05-15 |  | 19d | 0d |
| 67 | 5.3 | DEMOLICIÓN DE ANDÉN E > A 12 CM. (INCLUYE RETIRO Y ACARREO LIBRE HASTA 5 KM.) |  | 2d | 2026-05-16 | 2026-05-18 | 66 | 19d | 0d |
| 68 | 5.4 | EXCAVACIÓN MANUAL EN MATERIAL COMÚN |  | 3d | 2026-05-19 | 2026-05-21 | 67 | 19d | 0d |
| 69 | 5.5 | ESTRUCTURA EN CONCRETO | milestone | 0d | 2026-05-15 | 2026-05-15 |  | 65d |  |
| 70 | 5.6 | PLATINAS ENVEVIDAS DE SOPORTE PARA COLUMNAS DE ACERO |  | 2d | 2026-05-22 | 2026-05-23 | 68 | 57d |  |
| 71 | 5.7 | CONCRETO SIMPLE DE 28 Mpa. (4000 PSI) |  | 4d | 2026-05-22 | 2026-05-26 | 68 | 49d | 0d |
| 72 | 5.8 | RELLENO EN RECEBO COMPACTADO B200 |  | 3d | 2026-05-27 | 2026-05-29 | 71 | 49d | 0d |
| 73 | 5.9 | POCETA EN LADRILLO Y ENCHAPE DE 0.6 m * 0.4 m |  | 3d | 2026-05-30 | 2026-06-02 | 72 | 49d |  |
| 74 | 5.10 | ESTRUCTURA METALICA | milestone | 0d | 2026-05-15 | 2026-05-15 |  | 65d |  |
| 75 | 5.11 | SUMINISTRO, TRANSPORTE, FABRICACIÓN, FIGURADA Y/O ROLADO, ENSAMBLAJE Y MONTAJE MANUAL DE ESTRUCTURA METALICA INCLUYE PEDESTAL |  | 15d | 2026-05-22 | 2026-06-08 | 68 | 19d | 0d |
| 76 | 5.12 | SUMINISTRO E INSTALACIÓN DE ESMALTE SINTÉTICO PARA ESTRUCTURA METALICA. (INCLUYE BASE EN ANTICORROSIVO). |  | 5d | 2026-06-09 | 2026-06-13 | 75 | 19d | 0d |
| 77 | 5.13 | SUMINISTRO E INSTALACION CUBIERTA EN PERFILERIA METALICA, TEJA UPVC COLOR SEGÚN DISEÑO |  | 6d | 2026-06-15 | 2026-06-20 | 76 | 19d | 0d |
| 78 | 5.14 | SUMINISTRO E INSTALACION DE CANAL EN LAMINA COLD ROLLED CAL. 20 D=0.75 CON PINTURA Y ANTICORROSIVO |  | 6d | 2026-06-22 | 2026-06-27 | 77 | 19d | 0d |
| 79 | 5.15 | SUMINISTRO E INSTALACION LAMINA EN SUPERBOARD DE 10 MM |  | 8d | 2026-06-29 | 2026-07-07 | 78 | 19d |  |
| 80 | 5.16 | SUMINISTRO E INSTALACION PISO CERÁMICA BLANCO 50X50 |  | 6d | 2026-06-29 | 2026-07-04 | 78 | 21d |  |
| 81 | 5.17 | REJILLA DE VENTILACION 20X50 CM |  | 4d | 2026-06-29 | 2026-07-02 | 78 | 23d |  |
| 82 | 5.18 | Camerino individual para cambio de ropa, con estructura metálica, puerta metálica con cerradura, banco interior y accesorios. Incluye materiales, mano de obra 1.20*1.20 m |  | 6d | 2026-06-09 | 2026-06-15 | 75 | 38d |  |
| 83 | 5.19 | INSTALACIONES ELECTRICAS | milestone | 0d | 2026-05-15 | 2026-05-15 |  | 65d |  |
| 84 | 5.20 | SUMINISTRO E INSTALACION SALIDA DE ILUMINACION |  | 3d | 2026-06-09 | 2026-06-11 | 75 | 38d | 0d |
| 85 | 5.21 | SUMINISTRO E INSTALACION PUNTO ELECTRICO INTERRUPTOR |  | 3d | 2026-06-12 | 2026-06-15 | 84 | 38d |  |
| 86 | 5.22 | SUMINISTRO E INSTALACION TOMA DOBLE INCLUYE APARATO |  | 3d | 2026-06-12 | 2026-06-15 | 84 | 38d |  |
| 87 | 5.23 | SUMINISTRO E INSTALACION LUMINARIA LINEAL LED COMERCIAL 40 W LUZ DIA |  | 3d | 2026-06-12 | 2026-06-15 | 84 | 38d |  |
| 88 | 5.24 | INSTALACIONES HIDROSANITARIAS E HIDRAULICAS | milestone | 0d | 2026-05-15 | 2026-05-15 |  | 65d |  |
| 89 | 5.25 | SUMINISTRO E INSTALACION DE SANITARIO AHORRADOR CON ACOPLE |  | 3d | 2026-06-09 | 2026-06-11 | 75 | 35d | 0d |
| 90 | 5.26 | SUMINISTRO E INSTALACIÓN DE ORINAL INFANTIL LINEA INSTITUCIONAL. (INCLUYE ACCESORIOS) |  | 3d | 2026-06-12 | 2026-06-15 | 89 | 35d | 0d |
| 91 | 5.27 | SUMINISTRO E INSTALACION DE INCRUSTACIONES Y ESPEJO PARA BAÑO |  | 3d | 2026-06-16 | 2026-06-18 | 90 | 35d |  |
| 92 | 5.28 | SUMINISTRO E INSTALACION PUNTO HIDRAULICO 1/2" |  | 6d | 2026-06-12 | 2026-06-18 | 75, 89 | 35d |  |
| 93 | 5.29 | SUMINISTRO E INSTALACION LAVAMANOS SENCILLO CON ACOPLE |  | 3d | 2026-06-12 | 2026-06-15 | 89 | 38d |  |
| 94 | 5.30 | ASEO Y RETIRO DE ESCOMBROS | milestone | 0d | 2026-05-15 | 2026-05-15 |  | 65d |  |
| 95 | 5.31 | RETIRO DE ESCOMBROS |  | 1d | 2026-06-12 | 2026-06-12 | 89 | 40d | 0d |
| 96 | 5.32 | ASEO FINAL |  | 1d | 2026-06-12 | 2026-06-12 | 95FS-1d | 40d |  |
| 97 | 6 | FIN | milestone | 0d | 2026-03-02 | 2026-03-02 | 1 | 127d |  |
