# BP CALLE 61 NQS

Schedule from MS Project, 2026-03-02 to 2026-06-15.

## Calendars

- BP BOGOTA: Mon-Sat 08:00-12:00, 13:00-17:00; Sun off.

## Schedule

| ID | WBS | Task | Type | Duration | Start | Finish | Predecessors | Total slack | Free slack |
| --- | --- | --- | --- | --- | --- | --- | --- | --- | --- |
| 1 | 1 | INCIO | milestone | 0d | 2026-03-02 | 2026-03-02 |  | 5d | 0d |
| 2 | 2 | **ACTIVIDADES DE GESTION AMERICAS CON 26** |  | 30d | 2026-03-02 | 2026-04-04 | 1 |  |  |
| 3 | 2.1 | TRAMITE ADMISTRATIVO |  | 10d | 2026-03-02 | 2026-03-12 |  | 5d | 0d |
| 4 | 2.2 | TRAMITE LEGAL |  | 10d | 2026-03-13 | 2026-03-24 | 3 | 5d | 0d |
| 5 | 2.3 | AUTORIZACION AUTOMATICA |  | 5d | 2026-03-13 | 2026-03-18 | 3 | 5d |  |
| 6 | 2.4 | AUTORIZACION LEGAL |  | 5d | 2026-03-25 | 2026-03-30 | 4 | 5d |  |
| 7 | 3 | **URBANISMO** |  | 71d | 2026-03-25 | 2026-06-15 | 2FS-10d | 0d |  |
| 8 | 3.1 | PRELIMINARES | milestone | 0d | 2026-03-25 | 2026-03-25 | 5 | 0d |  |
| 9 | 3.2 | LOCALIZACIÓN Y REPLANTEO OBRA ARQUITECTÓNICA |  | 2d | 2026-03-25 | 2026-03-26 | 8 | 0d |  |
| 10 | 3.3 | CERRAMIENTO EN VARA ROLLIZA Y LONA H=1.50 M . DISTANCIA ENTRE POSTES 2 M |  | 12d | 2026-03-27 | 2026-04-09 | 9 | 0d |  |
| 11 | 3.4 | DEMOLICIÓN DE ANDÉN E > A 12 CM. (INCLUYE RETIRO Y ACARREO LIBRE HASTA 5 KM.) |  | 10d | 2026-04-10 | 2026-04-21 | 10 | 0d |  |
| 12 | 3.5 | EXCAVACIÓN MANUAL EN MATERIAL COMÚN |  | 10d | 2026-04-22 | 2026-05-02 | 11 | 0d |  |
| 13 | 3.6 | RELLENO EN RECEBO COMPACTADO B200 |  | 5d | 2026-05-04 | 2026-05-08 | 12 | 32d |  |
| 14 | 3.7 | ELEMENTOS URBANOS | milestone | 0d | 2026-05-02 | 2026-05-02 | 12 | 37d |  |
| 15 | 3.8 | BANCAS EN LADRILLO SEMI-PRENZADO CON DOBELAS EN CONCRETO, IMPERMEABILIZADAS 2x4 |  | 18d | 2026-05-04 | 2026-05-23 | 12 | 19d |  |
| 16 | 3.9 | SUMINISTRO E INSTALACIÓN DE CAMARAS DE CIBERSEGURIDAD CIRCUITO CERRADO INCLUIDO CONECTIVIDAD WIFI |  | 12d | 2026-05-04 | 2026-05-16 | 12 | 25d |  |
| 17 | 3.10 | PISOS Y ACABADOS ARQUITECTONICOS | milestone | 0d | 2026-03-25 | 2026-03-25 |  | 71d |  |
| 18 | 3.11 | CERRAMIENTO EN MALLA ESLABONADA CAL 10 (INCLUYE TUBO AGUA NEGRA DE 2" Y ANGULO 1" X 1" X 1/8") h=1.8 m |  | 25d | 2026-05-04 | 2026-06-01 | 12 | 0d |  |
| 19 | 3.12 | SUMINISTRO E INSTALACIÓN DE ADOQUÍN PARA EXTERIORES FORMATO 15X18, COLOR TERRACOTA. |  | 15d | 2026-05-04 | 2026-05-20 | 12 | 22d |  |
| 20 | 3.13 | INSTALACIONES ELECTRICAS Y DE DATOS | milestone | 0d | 2026-03-25 | 2026-03-25 |  | 71d |  |
| 21 | 3.14 | SUMINISTRO E INSTALACIÓN DE ELEMENTOS DE ACOMETIDA AÉREA. CONEXIÓN DESDE RED TRENZADA DE B.T., BAJANTE HACIA EQUIPO DE MEDIDA EN TUBO IMC DE 1". |  | 2d | 2026-06-02 | 2026-06-03 | 18 | 0d |  |
| 22 | 3.15 | SUMINISTRO E INSTALACION TOMA DOBLE INCLUYE APARATO NO INCLUYE CABLE |  | 4d | 2026-06-04 | 2026-06-08 | 21 | 0d |  |
| 23 | 3.16 | SUMINISTRO E INSTALACION LUMINARIA LINEAL LED COMERCIAL 40 W LUZ DIA NO INCLUYE CABLE |  | 6d | 2026-06-09 | 2026-06-15 | 22 | 0d |  |
| 24 | 3.17 | INSTALACIONES HIDROSANITARIAS Y GAS | milestone | 0d | 2026-03-25 | 2026-03-25 |  | 71d |  |
| 25 | 3.18 | PAGO ACOMETIDA DE ACUEDUCTO Y ALCANTARILLADO |  | 2d | 2026-03-27 | 2026-03-28 | 9 | 45d | 0d |
| 26 | 3.19 | SUMINISTRO E INSTALACION TUBERÍA HIDRÁULICA HIDRAULICO 1/2" DE DISTRIBUCIÓN |  | 8d | 2026-04-08 | 2026-04-16 | 28 | 45d | 0d |
| 27 | 3.20 | SUMINISTRO E INSTALACION TUBERÍA SANITARIA DE RECOLECCIÓN 3" |  | 6d | 2026-04-17 | 2026-04-23 | 26 | 45d |  |
| 28 | 3.21 | EXCAVACIÓN MANUAL EN MATERIAL COMÚN |  | 8d | 2026-03-30 | 2026-04-07 | 25 | 45d | 0d |
| 29 | 3.22 | RELLENO EN RECEBO COMPACTADO B200 |  | 8d | 2026-04-08 | 2026-04-16 | 28 | 51d |  |
| 30 | 3.23 | SUMINISTRO E INSTALACIÓN DE CUARTO PARA GAS |  | 4d | 2026-03-30 | 2026-04-02 | 25 | 61d | 0d |
| 31 | 3.24 | ASEO Y RETIRO DE ESCOMBROS | milestone | 0d | 2026-03-25 | 2026-03-25 |  | 71d |  |
| 32 | 3.25 | RETIRO DE ESCOMBROS |  | 1d | 2026-04-03 | 2026-04-03 | 30 | 61d | 0d |
| 33 | 3.26 | ASEO FINAL |  | 1d | 2026-04-04 | 2026-04-04 | 32 | 61d |  |

| ID | WBS | Task | Type | Duration | Start | Finish | Predecessors | Total slack | Free slack | Constraint |
| --- | --- | --- | --- | --- | --- | --- | --- | --- | --- | --- |
| 34 | 4 | **MODULO TIENDAS** |  | 52d | 2026-03-25 | 2026-05-23 | 2FS-10d | 19d |  |  |
| 35 | 4.1 | PRELIMINARES | milestone | 0d | 2026-03-25 | 2026-03-25 |  | 71d |  |  |
| 36 | 4.2 | LOCALIZACIÓN Y REPLANTEO |  | 2d | 2026-03-25 | 2026-03-26 |  | 19d | 0d |  |
| 37 | 4.3 | DEMOLICIÓN DE ANDÉN E > A 12 CM. (INCLUYE RETIRO Y ACARREO LIBRE HASTA 5 KM.) |  | 10d | 2026-03-27 | 2026-04-07 | 36 | 33d | 0d |  |
| 38 | 4.4 | EXCAVACIÓN MANUAL EN MATERIAL COMÚN |  | 10d | 2026-04-08 | 2026-04-18 | 37 | 33d | 0d |  |
| 39 | 4.5 | ESTRUCTURA EN CONCRETO | milestone | 0d | 2026-04-18 | 2026-04-18 | 38 | 49d |  |  |
| 40 | 4.6 | SUMINISTRO E INSTALACION DE DADOS EN CONCRETO SIMPLE DE 4000 PSIDE 30X30 CMS |  | 12d | 2026-04-20 | 2026-05-02 | 38 | 37d |  |  |
| 41 | 4.7 | CONCRETO SIMPLE DE 28 Mpa. (4000 PSI) |  | 8d | 2026-04-20 | 2026-04-28 | 38 | 33d | 0d |  |
| 42 | 4.8 | RELLENO EN RECEBO COMPACTADO B200 |  | 8d | 2026-04-29 | 2026-05-07 | 41 | 33d |  |  |
| 43 | 4.9 | ESTRUCTURA METALICA | milestone | 0d | 2026-03-25 | 2026-03-25 |  | 71d |  |  |
| 44 | 4.10 | SUMINISTRO, TRANSPORTE, FABRICACIÓN, FIGURADA Y/O ROLADO, ENSAMBLAJE Y MONTAJE MANUAL DE ESTRUCTURA METALICA |  | 25d | 2026-03-27 | 2026-04-24 | 36 | 19d | 0d |  |
| 45 | 4.11 | SUMINISTRO E INSTALACIÓN DE ESMALTE SINTÉTICO PARA ESTRUCTURA METALICA. (INCLUYE BASE EN ANTICORROSIVO). |  | 8d | 2026-04-25 | 2026-05-04 | 44 | 32d | 0d |  |
| 46 | 4.12 | SUMINISTRO E INSTALACION CUBIERTA EN PERFILERIA METALICA, TEJA UPVC COLOR SEGÚN DISEÑO ESPESOR 6 MM. |  | 12d | 2026-04-25 | 2026-05-08 | 44 | 19d | 0d |  |
| 47 | 4.13 | SUMINISTRO E INSTALACION DE CANAL EN LAMINA COLD ROLLED CAL. 20 D=0.75 CON PINTURA Y ANTICORROSIVO |  | 10d | 2026-04-25 | 2026-05-06 | 44 | 24d | 0d | start no earlier than 2026-03-02 |
| 48 | 4.14 | SUMINISTRO E INSTALACION LAMINA EN SUPERBOARD DE 10 MM |  | 10d | 2026-05-09 | 2026-05-20 | 46 | 19d | 0d |  |
| 49 | 4.15 | Suministro e instalación de lámina microperforada en acero galvanizado |  | 4d | 2026-05-05 | 2026-05-08 | 45 | 32d |  |  |
| 50 | 4.16 | SUMINISTRO E INSTALACIÓN DE MESÓN 60 CM ANCHO EN LÁMINA GALVANIZADA CALIBRE 22 CON SOPORTES Y ANGULOS A=45 CM, PINTURA ELECTROSTÁTICA |  | 3d | 2026-05-21 | 2026-05-23 | 48 | 19d |  |  |
| 51 | 4.17 | POCETA EN LADRILLO Y ENCHAPE DE 0.6 m * 0.4 m |  | 3d | 2026-05-21 | 2026-05-23 | 48 | 19d |  |  |
| 52 | 4.18 | INSTALACIONES ELECTRICAS | milestone | 0d | 2026-05-06 | 2026-05-06 | 47 | 24d | 0d |  |
| 53 | 4.19 | SUMINISTRO E INSTALACION SALIDA DE ILUMINACION |  | 4d | 2026-05-07 | 2026-05-11 | 52 | 30d |  |  |
| 54 | 4.20 | SUMINISTRO E INSTALACION PUNTO ELECTRICO INTERRUPTOR |  | 4d | 2026-05-07 | 2026-05-11 | 52 | 30d |  |  |
| 55 | 4.21 | SUMINISTRO E INSTALACION TOMA DOBLE INCLUYE APARATO |  | 4d | 2026-05-07 | 2026-05-11 | 52 | 30d |  |  |
| 56 | 4.22 | SUMINISTRO E INSTALACION LUMINARIA LINEAL LED COMERCIAL 40 W LUZ DIA |  | 6d | 2026-05-07 | 2026-05-13 | 52 | 28d |  |  |
| 57 | 4.23 | INSTALACIONES HIDROSANITARIAS E HIDRAULICAS | milestone | 0d | 2026-05-06 | 2026-05-06 | 52 | 24d | 0d |  |
| 58 | 4.24 | SUMINISTRO E INSTALACION LAVAPLATOS SENCILLO EN ACERO INOXIDABLE |  | 6d | 2026-05-07 | 2026-05-13 | 57 | 28d |  |  |
| 59 | 4.25 | SUMINISTRO E INSTALACION PUNTO HIDRAULICO 1/2" |  | 6d | 2026-05-07 | 2026-05-13 | 57 | 24d | 0d |  |
| 60 | 4.26 | ASEO Y RETIRO DE ESCOMBROS | milestone | 0d | 2026-05-13 | 2026-05-13 | 59 | 28d |  |  |
| 61 | 4.27 | RETIRO DE ESCOMBROS |  | 2d | 2026-05-14 | 2026-05-15 | 59 | 24d | 0d |  |
| 62 | 4.28 | ASEO FINAL |  | 2d | 2026-05-16 | 2026-05-18 | 61 | 24d |  |  |

| ID | WBS | Task | Type | Duration | Start | Finish | Predecessors | Total slack | Free slack |
| --- | --- | --- | --- | --- | --- | --- | --- | --- | --- |
| 63 | 5 | **MODULO BAÑOS** |  | 40d | 2026-03-25 | 2026-05-09 | 2FS-10d | 31d |  |
| 64 | 5.1 | PRELIMINARES | milestone | 0d | 2026-03-25 | 2026-03-25 |  | 71d |  |
| 65 | 5.2 | LOCALIZACIÓN Y REPLANTEO |  | 1d | 2026-03-25 | 2026-03-25 |  | 31d | 0d |
| 66 | 5.3 | DEMOLICIÓN DE ANDÉN E > A 12 CM. (INCLUYE RETIRO Y ACARREO LIBRE HASTA 5 KM.) |  | 4d | 2026-03-26 | 2026-03-30 | 65 | 31d | 0d |
| 67 | 5.4 | EXCAVACIÓN MANUAL EN MATERIAL COMÚN |  | 4d | 2026-03-31 | 2026-04-03 | 66 | 31d | 0d |
| 68 | 5.5 | ESTRUCTURA EN CONCRETO | milestone | 0d | 2026-03-25 | 2026-03-25 |  | 71d |  |
| 69 | 5.6 | PLATINAS ENVEVIDAS DE SOPORTE PARA COLUMNAS DE ACERO |  | 3d | 2026-04-04 | 2026-04-07 | 67 | 52d | 0d |
| 70 | 5.7 | CONCRETO SIMPLE DE 28 Mpa. (4000 PSI) |  | 4d | 2026-04-08 | 2026-04-11 | 69 | 52d | 0d |
| 71 | 5.8 | RELLENO EN RECEBO COMPACTADO B200 |  | 2d | 2026-04-08 | 2026-04-09 | 69 | 57d |  |
| 72 | 5.9 | POCETA EN LADRILLO Y ENCHAPE DE 0.6 m * 0.4 m |  | 3d | 2026-04-13 | 2026-04-15 | 70 | 52d |  |
| 73 | 5.10 | ESTRUCTURA METALICA | milestone | 0d | 2026-03-25 | 2026-03-25 |  | 71d |  |
| 74 | 5.11 | SUMINISTRO, TRANSPORTE, FABRICACIÓN, FIGURADA Y/O ROLADO, ENSAMBLAJE Y MONTAJE MANUAL DE ESTRUCTURA METALICA INCLUYE PEDESTAL |  | 11d | 2026-04-04 | 2026-04-16 | 67 | 31d | 0d |
| 75 | 5.12 | SUMINISTRO E INSTALACIÓN DE ESMALTE SINTÉTICO PARA ESTRUCTURA METALICA. (INCLUYE BASE EN ANTICORROSIVO). |  | 4d | 2026-04-17 | 2026-04-21 | 74 | 31d | 0d |
| 76 | 5.13 | SUMINISTRO E INSTALACION CUBIERTA EN PERFILERIA METALICA, TEJA UPVC COLOR SEGÚN DISEÑO |  | 6d | 2026-04-22 | 2026-04-28 | 75 | 31d | 0d |
| 77 | 5.14 | SUMINISTRO E INSTALACION DE CANAL EN LAMINA COLD ROLLED CAL. 20 D=0.75 CON PINTURA Y ANTICORROSIVO |  | 4d | 2026-04-29 | 2026-05-02 | 76 | 37d |  |
| 78 | 5.15 | SUMINISTRO E INSTALACION LAMINA EN SUPERBOARD DE 10 MM |  | 4d | 2026-04-29 | 2026-05-02 | 76 | 31d | 0d |
| 79 | 5.16 | SUMINISTRO E INSTALACION PISO CERÁMICA BLANCO 50X50 |  | 4d | 2026-05-04 | 2026-05-07 | 78 | 33d |  |
| 80 | 5.17 | REJILLA DE VENTILACION 20X50 CM |  | 2d | 2026-05-04 | 2026-05-05 | 78 | 35d |  |
| 81 | 5.18 | Camerino individual para cambio de ropa, con estructura metálica, puerta metálica con cerradura, banco interior y accesorios. Incluye materiales, mano de obra 1.20*1.20 m |  | 6d | 2026-04-17 | 2026-04-23 | 74 | 45d |  |
| 82 | 5.19 | INSTALACIONES ELECTRICAS | milestone | 0d | 2026-03-25 | 2026-03-25 |  | 71d |  |
| 83 | 5.20 | SUMINISTRO E INSTALACION SALIDA DE ILUMINACION |  | 3d | 2026-05-04 | 2026-05-06 | 78 | 34d |  |
| 84 | 5.21 | SUMINISTRO E INSTALACION PUNTO ELECTRICO INTERRUPTOR |  | 3d | 2026-05-04 | 2026-05-06 | 78 | 34d |  |
| 85 | 5.22 | SUMINISTRO E INSTALACION TOMA DOBLE INCLUYE APARATO |  | 3d | 2026-05-04 | 2026-05-06 | 78 | 34d |  |
| 86 | 5.23 | SUMINISTRO E INSTALACION LUMINARIA LINEAL LED COMERCIAL 40 W LUZ DIA |  | 3d | 2026-05-04 | 2026-05-06 | 78 | 34d |  |
| 87 | 5.24 | INSTALACIONES HIDROSANITARIAS E HIDRAULICAS | milestone | 0d | 2026-03-25 | 2026-03-25 |  | 71d |  |
| 88 | 5.25 | SUMINISTRO E INSTALACION DE SANITARIO AHORRADOR CON ACOPLE |  | 3d | 2026-05-04 | 2026-05-06 | 78 | 34d |  |
| 89 | 5.26 | SUMINISTRO E INSTALACIÓN DE ORINAL INFANTIL LINEA INSTITUCIONAL. (INCLUYE ACCESORIOS) |  | 3d | 2026-05-04 | 2026-05-06 | 78 | 34d |  |
| 90 | 5.27 | SUMINISTRO E INSTALACION DE INCRUSTACIONES Y ESPEJO PARA BAÑO |  | 3d | 2026-05-04 | 2026-05-06 | 78 | 34d |  |
| 91 | 5.28 | SUMINISTRO E INSTALACION PUNTO HIDRAULICO 1/2" |  | 4d | 2026-05-04 | 2026-05-07 | 78 | 33d |  |
| 92 | 5.29 | SUMINISTRO E INSTALACION LAVAMANOS SENCILLO CON ACOPLE |  | 2d | 2026-05-04 | 2026-05-05 | 78 | 31d | 0d |
| 93 | 5.30 | ASEO Y RETIRO DE ESCOMBROS | milestone | 0d | 2026-03-25 | 2026-03-25 |  | 71d |  |
| 94 | 5.31 | RETIRO DE ESCOMBROS |  | 2d | 2026-05-06 | 2026-05-07 | 92 | 31d | 0d |
| 95 | 5.32 | ASEO FINAL |  | 2d | 2026-05-08 | 2026-05-09 | 94 | 31d |  |
| 96 | 6 | FIN | milestone | 0d | 2026-03-02 | 2026-03-02 | 1 | 30d |  |
