# BP AMERICAS AV 30

Schedule from MS Project, 2026-03-02 to 2026-09-10.

## Calendars

- BP BOGOTA: Mon-Sat 08:00-12:00, 13:00-17:00; Sun off.

## Schedule

| ID | WBS | Task | Type | Duration | Start | Finish | Predecessors | Total slack | Free slack |
| --- | --- | --- | --- | --- | --- | --- | --- | --- | --- |
| 1 | 1 | INCIO | milestone | 0d | 2026-03-02 | 2026-03-02 |  | 5d | 0d |
| 2 | 2 | **ACTIVIDADES DE GESTION AMERICAS CON 26** |  | 30d | 2026-03-02 | 2026-04-04 | 1 |  |  |
| 3 | 2.1 | TRAMITE ADMISTRATIVO |  | 10d | 2026-03-02 | 2026-03-12 |  | 5d | 0d |
| 4 | 2.2 | TRAMITE LEGAL |  | 10d | 2026-03-13 | 2026-03-24 | 3 | 5d | 0d |
| 5 | 2.3 | AUTORIZACION AUTOMATICA |  | 5d | 2026-03-25 | 2026-03-30 | 4 | 5d |  |
| 6 | 2.4 | AUTORIZACION LEGAL |  | 5d | 2026-03-25 | 2026-03-30 | 4 | 5d |  |
| 7 | 3 | **URBANISMO** |  | 81d | 2026-04-04 | 2026-07-08 | 2 | 0d |  |
| 8 | 3.1 | PRELIMINARES | milestone | 0d | 2026-04-04 | 2026-04-04 |  | 81d |  |
| 9 | 3.2 | LOCALIZACIÓN Y REPLANTEO OBRA ARQUITECTÓNICA |  | 3d | 2026-04-06 | 2026-04-08 |  | 0d |  |
| 10 | 3.3 | CERRAMIENTO EN VARA ROLLIZA Y LONA H=1.50 M . DISTANCIA ENTRE POSTES 2 M |  | 10d | 2026-04-09 | 2026-04-20 | 9 | 0d |  |
| 11 | 3.4 | DEMOLICIÓN DE ANDÉN E > A 12 CM. (INCLUYE RETIRO Y ACARREO LIBRE HASTA 5 KM.) |  | 15d | 2026-04-21 | 2026-05-07 | 10 | 0d |  |
| 12 | 3.5 | EXCAVACIÓN MANUAL EN MATERIAL COMÚN PARA ISNTALACIONES |  | 10d | 2026-05-08 | 2026-05-19 | 11 | 0d |  |
| 13 | 3.6 | RELLENO EN RECEBO COMPACTADO B200 |  | 8d | 2026-05-20 | 2026-05-28 | 12 | 25d | 0d |
| 14 | 3.7 | ELEMENTOS URBANOS | milestone | 0d | 2026-04-04 | 2026-04-04 |  | 81d |  |
| 15 | 3.8 | SUMINISTRO, INSTALACION Y COMPACTACION DE MEZCLA ASFALTICA DE PLACA DE PARQUEADERO EN PAVIMENTO FLÉXIBLE |  | 10d | 2026-05-29 | 2026-06-09 | 13 | 25d |  |
| 16 | 3.9 | IMPRIMACIÓN CON EMULSIÓN ASFÁLTICA CRL-1H |  | 2d | 2026-05-29 | 2026-05-30 | 13 | 33d |  |
| 17 | 3.10 | CERRAMIENTO EN MALLA ESLABONADA CAL 10 (INCLUYE TUBO AGUA NEGRA DE 2" Y ANGULO 1" X 1" X 1/8") |  | 20d | 2026-05-20 | 2026-06-11 | 12 | 0d |  |
| 18 | 3.11 | PISOS Y ACABADOS ARQUITECTONICOS | milestone | 0d | 2026-04-04 | 2026-04-04 |  | 81d |  |
| 19 | 3.12 | SUMINISTRO E INSTALACIÓN DE ADOQUÍN PARA EXTERIORES FORMATO 15X18, COLOR TERRACOTA. |  | 20d | 2026-06-12 | 2026-07-04 | 17 | 3d |  |
| 20 | 3.13 | MATERAS EN LADRILLO COMÚN (CON INPERMEABILIZACIÓN, H=60 CM) PASTO NATURAL |  | 20d | 2026-06-12 | 2026-07-04 | 17 | 3d |  |
| 21 | 3.14 | INSTALACIONES ELECTRICAS Y DE DATOS | milestone | 0d | 2026-04-04 | 2026-04-04 |  | 81d |  |
| 22 | 3.15 | SUMINISTRO, INSTALACIÓN DE BARRERA VEHICULAR AUTOMÁTICA |  | 15d | 2026-06-12 | 2026-06-29 | 17 | 0d |  |
| 23 | 3.16 | SUMINISTRO E INSTALACIÓN DE ELEMENTOS DE ACOMETIDA AÉREA. CONEXIÓN DESDE RED TRENZADA DE B.T., BAJANTE HACIA EQUIPO DE MEDIDA EN TUBO IMC DE 1". |  | 8d | 2026-06-12 | 2026-06-20 | 17 | 3d | 0d |
| 24 | 3.17 | SUMINISTRO E TENDIDO DE CABLE UTP CATEGORÍA 6A |  | 4d | 2026-06-30 | 2026-07-03 | 22 | 0d |  |
| 25 | 3.18 | SUMINISTRO E INSTALACION DE PUNTO DE INTERNET NO INCLUYE CABLE |  | 4d | 2026-07-04 | 2026-07-08 | 24 | 0d |  |
| 26 | 3.19 | SUMINISTRO, INSTALACIÓN Y CONEXIONADO DE CABLE CONCENTRICO (ANTIFRAUDE) No. 2 x 6 +6 AWG EN COBRE PARA ACOMETIDA BIFÁSICA |  | 6d | 2026-06-22 | 2026-06-27 | 23 | 3d | 0d |
| 27 | 3.20 | SUMINISTRO E INSTALACION TOMA DOBLE INCLUYE APARATO NO INCLUYE CABLE |  | 6d | 2026-06-30 | 2026-07-06 | 22 | 2d |  |
| 28 | 3.21 | SUMINISTRO E INSTALACION LUMINARIA LINEAL LED COMERCIAL 40 W LUZ DIA NO INCLUYE CABLE |  | 6d | 2026-06-29 | 2026-07-04 | 26 | 3d |  |
| 29 | 3.22 | INSTALACIONES HIDROSANITARIAS Y GAS | milestone | 0d | 2026-04-04 | 2026-04-04 |  | 81d |  |
| 30 | 3.23 | PAGO ACOMETIDA DE ACUEDUCTO Y ALCANTARILLADO |  | 3d | 2026-04-09 | 2026-04-11 | 9 | 50d | 0d |
| 31 | 3.24 | SUMINISTRO E INSTALACION TUBERÍA HIDRÁULICA HIDRAULICO 1/2" DE DISTRIBUCIÓN |  | 6d | 2026-04-13 | 2026-04-18 | 30 | 50d | 0d |
| 32 | 3.25 | SUMINISTRO E INSTALACION TUBERÍA SANITARIA DE RECOLECCIÓN 6" |  | 4d | 2026-04-20 | 2026-04-23 | 31 | 65d |  |
| 33 | 3.26 | EXCAVACIÓN MANUAL EN MATERIAL COMÚN |  | 6d | 2026-04-20 | 2026-04-25 | 30, 31 | 50d | 0d |
| 34 | 3.27 | RELLENO EN RECEBO COMPACTADO B200 |  | 3d | 2026-04-27 | 2026-04-29 | 33 | 50d | 0d |
| 35 | 3.28 | SUMINISTRO E INSTALACIÓN DE CUARTO PARA GAS |  | 6d | 2026-04-30 | 2026-05-06 | 34 | 50d | 0d |
| 36 | 3.29 | ASEO Y RETIRO DE ESCOMBROS | milestone | 0d | 2026-04-04 | 2026-04-04 |  | 81d |  |
| 37 | 3.30 | RETIRO DE ESCOMBROS |  | 2d | 2026-05-07 | 2026-05-08 | 35 | 50d | 0d |
| 38 | 3.31 | ASEO FINAL |  | 2d | 2026-05-09 | 2026-05-11 | 37 | 50d |  |

| ID | WBS | Task | Type | Duration | Start | Finish | Predecessors | Total slack | Free slack | Constraint |
| --- | --- | --- | --- | --- | --- | --- | --- | --- | --- | --- |
| 39 | 4 | **MODULO TIENDAS** |  | 65d | 2026-06-27 | 2026-09-10 | 7FS-10d | 0d |  |  |
| 40 | 4.1 | PRELIMINARES | milestone | 0d | 2026-06-27 | 2026-06-27 |  | 65d |  |  |
| 41 | 4.2 | LOCALIZACIÓN Y REPLANTEO |  | 2d | 2026-06-27 | 2026-06-29 |  | 0d |  |  |
| 42 | 4.3 | DEMOLICIÓN DE ANDÉN E > A 12 CM. (INCLUYE RETIRO Y ACARREO LIBRE HASTA 5 KM.) |  | 4d | 2026-06-30 | 2026-07-03 | 41 | 37d | 0d |  |
| 43 | 4.4 | EXCAVACIÓN MANUAL EN MATERIAL COMÚN |  | 8d | 2026-07-04 | 2026-07-13 | 42 | 37d | 0d |  |
| 44 | 4.5 | ESTRUCTURA EN CONCRETO | milestone | 0d | 2026-07-13 | 2026-07-13 | 43 | 51d |  |  |
| 45 | 4.6 | SUMINISTRO E INSTALACION DE DADOS EN CONCRETO SIMPLE DE 4000 PSIDE 30X30 CMS |  | 8d | 2026-07-14 | 2026-07-22 | 43 | 43d |  |  |
| 46 | 4.7 | CONCRETO SIMPLE DE 28 Mpa. (4000 PSI) |  | 8d | 2026-07-14 | 2026-07-22 | 43 | 37d | 0d |  |
| 47 | 4.8 | RELLENO EN RECEBO COMPACTADO B200 |  | 6d | 2026-07-23 | 2026-07-29 | 46 | 37d |  |  |
| 48 | 4.9 | ESTRUCTURA METALICA | milestone | 0d | 2026-06-27 | 2026-06-27 |  | 65d |  |  |
| 49 | 4.10 | SUMINISTRO, TRANSPORTE, FABRICACIÓN, FIGURADA Y/O ROLADO, ENSAMBLAJE Y MONTAJE MANUAL DE ESTRUCTURA METALICA |  | 25d | 2026-06-30 | 2026-07-28 | 41 | 0d |  |  |
| 50 | 4.11 | SUMINISTRO E INSTALACIÓN DE ESMALTE SINTÉTICO PARA ESTRUCTURA METALICA. (INCLUYE BASE EN ANTICORROSIVO). |  | 10d | 2026-07-29 | 2026-08-08 | 49 | 0d |  |  |
| 51 | 4.12 | SUMINISTRO E INSTALACION CUBIERTA EN PERFILERIA METALICA, TEJA UPVC COLOR SEGÚN DISEÑO ESPESOR 6 MM. |  | 10d | 2026-08-10 | 2026-08-20 | 50 | 0d |  |  |
| 52 | 4.13 | SUMINISTRO E INSTALACION DE CANAL EN LAMINA COLD ROLLED CAL. 20 D=0.75 CON PINTURA Y ANTICORROSIVO |  | 8d | 2026-08-21 | 2026-08-29 | 51 | 0d |  | start no earlier than 2026-03-02 |
| 53 | 4.14 | SUMINISTRO E INSTALACION LAMINA EN SUPERBOARD DE 10 MM |  | 10d | 2026-08-21 | 2026-09-01 | 51 | 4d | 0d |  |
| 54 | 4.15 | Suministro e instalación de lámina microperforada en acero galvanizado |  | 4d | 2026-08-10 | 2026-08-13 | 50 | 24d |  |  |
| 55 | 4.16 | SUMINISTRO E INSTALACIÓN DE MESÓN 60 CM ANCHO EN LÁMINA GALVANIZADA CALIBRE 22 CON SOPORTES Y ANGULOS A=45 CM, PINTURA ELECTROSTÁTICA |  | 4d | 2026-09-02 | 2026-09-05 | 53 | 4d |  |  |
| 56 | 4.17 | POCETA EN LADRILLO Y ENCHAPE DE 0.6 m * 0.4 m |  | 2d | 2026-09-02 | 2026-09-03 | 53 | 6d |  |  |
| 57 | 4.18 | INSTALACIONES ELECTRICAS | milestone | 0d | 2026-08-29 | 2026-08-29 | 52 | 0d |  |  |
| 58 | 4.19 | SUMINISTRO E INSTALACION SALIDA DE ILUMINACION |  | 4d | 2026-08-31 | 2026-09-03 | 57 | 6d |  |  |
| 59 | 4.20 | SUMINISTRO E INSTALACION PUNTO ELECTRICO INTERRUPTOR |  | 4d | 2026-08-31 | 2026-09-03 | 57 | 6d |  |  |
| 60 | 4.21 | SUMINISTRO E INSTALACION TOMA DOBLE INCLUYE APARATO |  | 4d | 2026-08-31 | 2026-09-03 | 57 | 6d |  |  |
| 61 | 4.22 | SUMINISTRO E INSTALACION LUMINARIA LINEAL LED COMERCIAL 40 W LUZ DIA |  | 6d | 2026-08-31 | 2026-09-05 | 57 | 4d |  |  |
| 62 | 4.23 | INSTALACIONES HIDROSANITARIAS E HIDRAULICAS | milestone | 0d | 2026-08-29 | 2026-08-29 | 57 | 0d |  |  |
| 63 | 4.24 | SUMINISTRO E INSTALACION LAVAPLATOS SENCILLO EN ACERO INOXIDABLE |  | 6d | 2026-08-31 | 2026-09-05 | 62 | 4d |  |  |
| 64 | 4.25 | SUMINISTRO E INSTALACION PUNTO HIDRAULICO 1/2" |  | 6d | 2026-08-31 | 2026-09-05 | 62 | 0d |  |  |
| 65 | 4.26 | ASEO Y RETIRO DE ESCOMBROS | milestone | 0d | 2026-09-05 | 2026-09-05 | 64 | 4d |  |  |
| 66 | 4.27 | RETIRO DE ESCOMBROS |  | 2d | 2026-09-07 | 2026-09-08 | 64 | 0d |  |  |
| 67 | 4.28 | ASEO FINAL |  | 2d | 2026-09-09 | 2026-09-10 | 66 | 0d |  |  |

| ID | WBS | Task | Type | Duration | Start | Finish | Predecessors | Total slack | Free slack |
| --- | --- | --- | --- | --- | --- | --- | --- | --- | --- |
| 68 | 5 | **MODULO BAÑOS** |  | 48d | 2026-06-27 | 2026-08-21 | 7FS-10d | 17d |  |
| 69 | 5.1 | PRELIMINARES | milestone | 0d | 2026-06-27 | 2026-06-27 |  | 65d |  |
| 70 | 5.2 | LOCALIZACIÓN Y REPLANTEO |  | 1d | 2026-06-27 | 2026-06-27 |  | 17d | 0d |
| 71 | 5.3 | DEMOLICIÓN DE ANDÉN E > A 12 CM. (INCLUYE RETIRO Y ACARREO LIBRE HASTA 5 KM.) |  | 2d | 2026-06-29 | 2026-06-30 | 70 | 50d | 0d |
| 72 | 5.4 | EXCAVACIÓN MANUAL EN MATERIAL COMÚN |  | 3d | 2026-07-01 | 2026-07-03 | 71 | 50d | 0d |
| 73 | 5.5 | ESTRUCTURA EN CONCRETO | milestone | 0d | 2026-06-27 | 2026-06-27 |  | 65d |  |
| 74 | 5.6 | PLATINAS ENVEVIDAS DE SOPORTE PARA COLUMNAS DE ACERO |  | 2d | 2026-07-04 | 2026-07-06 | 72 | 50d | 0d |
| 75 | 5.7 | CONCRETO SIMPLE DE 28 Mpa. (4000 PSI) |  | 4d | 2026-07-07 | 2026-07-10 | 74 | 50d | 0d |
| 76 | 5.8 | RELLENO EN RECEBO COMPACTADO B200 |  | 3d | 2026-07-07 | 2026-07-09 | 74 | 54d |  |
| 77 | 5.9 | POCETA EN LADRILLO Y ENCHAPE DE 0.6 m * 0.4 m |  | 3d | 2026-07-11 | 2026-07-14 | 75 | 50d |  |
| 78 | 5.10 | ESTRUCTURA METALICA | milestone | 0d | 2026-06-27 | 2026-06-27 |  | 65d |  |
| 79 | 5.11 | SUMINISTRO, TRANSPORTE, FABRICACIÓN, FIGURADA Y/O ROLADO, ENSAMBLAJE Y MONTAJE MANUAL DE ESTRUCTURA METALICA INCLUYE PEDESTAL |  | 15d | 2026-06-29 | 2026-07-15 | 70 | 17d | 0d |
| 80 | 5.12 | SUMINISTRO E INSTALACIÓN DE ESMALTE SINTÉTICO PARA ESTRUCTURA METALICA. (INCLUYE BASE EN ANTICORROSIVO). |  | 6d | 2026-07-16 | 2026-07-22 | 79 | 17d | 0d |
| 81 | 5.13 | SUMINISTRO E INSTALACION CUBIERTA EN PERFILERIA METALICA, TEJA UPVC COLOR SEGÚN DISEÑO |  | 8d | 2026-07-23 | 2026-07-31 | 80 | 17d | 0d |
| 82 | 5.14 | SUMINISTRO E INSTALACION DE CANAL EN LAMINA COLD ROLLED CAL. 20 D=0.75 CON PINTURA Y ANTICORROSIVO |  | 8d | 2026-08-01 | 2026-08-10 | 81 | 27d |  |
| 83 | 5.15 | SUMINISTRO E INSTALACION LAMINA EN SUPERBOARD DE 10 MM |  | 10d | 2026-08-01 | 2026-08-12 | 81 | 17d | 0d |
| 84 | 5.16 | SUMINISTRO E INSTALACION PISO CERÁMICA BLANCO 50X50 |  | 8d | 2026-08-13 | 2026-08-21 | 83 | 17d |  |
| 85 | 5.17 | REJILLA DE VENTILACION 20X50 CM |  | 4d | 2026-08-13 | 2026-08-17 | 83 | 21d |  |
| 86 | 5.18 | Camerino individual para cambio de ropa, con estructura metálica, puerta metálica con cerradura, banco interior y accesorios. Incluye materiales, mano de obra 1.20*1.20 m |  | 6d | 2026-07-16 | 2026-07-22 | 79 | 43d |  |
| 87 | 5.19 | INSTALACIONES ELECTRICAS | milestone | 0d | 2026-06-27 | 2026-06-27 |  | 65d |  |
| 88 | 5.20 | SUMINISTRO E INSTALACION SALIDA DE ILUMINACION |  | 3d | 2026-08-13 | 2026-08-15 | 83 | 22d |  |
| 89 | 5.21 | SUMINISTRO E INSTALACION PUNTO ELECTRICO INTERRUPTOR |  | 3d | 2026-08-13 | 2026-08-15 | 83 | 22d |  |
| 90 | 5.22 | SUMINISTRO E INSTALACION TOMA DOBLE INCLUYE APARATO |  | 3d | 2026-08-13 | 2026-08-15 | 83 | 22d |  |
| 91 | 5.23 | SUMINISTRO E INSTALACION LUMINARIA LINEAL LED COMERCIAL 40 W LUZ DIA |  | 3d | 2026-08-13 | 2026-08-15 | 83 | 22d |  |
| 92 | 5.24 | INSTALACIONES HIDROSANITARIAS E HIDRAULICAS | milestone | 0d | 2026-06-27 | 2026-06-27 |  | 65d |  |
| 93 | 5.25 | SUMINISTRO E INSTALACION DE SANITARIO AHORRADOR CON ACOPLE |  | 3d | 2026-08-13 | 2026-08-15 | 83 | 22d |  |
| 94 | 5.26 | SUMINISTRO E INSTALACIÓN DE ORINAL INFANTIL LINEA INSTITUCIONAL. (INCLUYE ACCESORIOS) |  | 3d | 2026-08-13 | 2026-08-15 | 83 | 22d |  |
| 95 | 5.27 | SUMINISTRO E INSTALACION DE INCRUSTACIONES Y ESPEJO PARA BAÑO |  | 3d | 2026-08-13 | 2026-08-15 | 83 | 22d |  |
| 96 | 5.28 | SUMINISTRO E INSTALACION PUNTO HIDRAULICO 1/2" |  | 8d | 2026-08-13 | 2026-08-21 | 83 | 17d |  |
| 97 | 5.29 | SUMINISTRO E INSTALACION LAVAMANOS SENCILLO CON ACOPLE |  | 3d | 2026-08-13 | 2026-08-15 | 83 | 18d | 0d |
| 98 | 5.30 | ASEO Y RETIRO DE ESCOMBROS | milestone | 0d | 2026-06-27 | 2026-06-27 |  | 65d |  |
| 99 | 5.31 | RETIRO DE ESCOMBROS |  | 2d | 2026-08-17 | 2026-08-18 | 97 | 18d | 0d |
| 100 | 5.32 | ASEO FINAL |  | 2d | 2026-08-19 | 2026-08-20 | 99 | 18d |  |
| 101 | 6 | FIN | milestone | 0d | 2026-03-02 | 2026-03-02 | 1 | 40d |  |
