# BP CALLE 3

Schedule from MS Project, 2026-03-02 to 2026-06-15.

## Calendars

- BP BOGOTA: Mon-Sat 08:00-12:00, 13:00-17:00; Sun off.

## Schedule

| ID | WBS | Task | Type | Duration | Start | Finish | Predecessors | Total slack | Free slack |
| --- | --- | --- | --- | --- | --- | --- | --- | --- | --- |
| 1 | 1 | INCIO | milestone | 0d | 2026-03-02 | 2026-03-02 |  | 10d | 0d |
| 2 | 2 | **ACTIVIDADES DE GESTION AMERICAS CON 26** |  | 30d | 2026-03-02 | 2026-04-04 | 1 |  |  |
| 3 | 2.1 | TRAMITE ADMISTRATIVO |  | 10d | 2026-03-02 | 2026-03-12 |  | 10d | 0d |
| 4 | 2.2 | TRAMITE LEGAL |  | 10d | 2026-03-13 | 2026-03-24 | 3 | 10d |  |
| 5 | 2.3 | AUTORIZACION AUTOMATICA |  | 5d | 2026-03-13 | 2026-03-18 | 3 | 15d |  |
| 6 | 2.4 | AUTORIZACION LEGAL |  | 5d | 2026-03-13 | 2026-03-18 | 3 | 15d |  |
| 7 | 3 | **URBANISMO** |  | 71d | 2026-03-25 | 2026-06-15 | 2FS-10d | 0d |  |
| 8 | 3.1 | PRELIMINARES | milestone | 0d | 2026-03-25 | 2026-03-25 |  | 34d |  |
| 9 | 3.2 | LOCALIZACIÓN Y REPLANTEO OBRA ARQUITECTÓNICA |  | 1d | 2026-03-25 | 2026-03-25 |  | 0d |  |
| 10 | 3.3 | CERRAMIENTO EN VARA ROLLIZA Y LONA H=1.50 M . DISTANCIA ENTRE POSTES 2 M |  | 15d | 2026-03-26 | 2026-04-11 | 9 | 0d |  |
| 11 | 3.4 | DEMOLICIÓN DE ANDÉN E > A 12 CM. (INCLUYE RETIRO Y ACARREO LIBRE HASTA 5 KM.) |  | 8d | 2026-04-13 | 2026-04-21 | 10 | 0d |  |
| 12 | 3.5 | EXCAVACIÓN MANUAL EN MATERIAL COMÚN |  | 12d | 2026-04-13 | 2026-04-25 | 10 | 28d | 0d |
| 13 | 3.6 | RELLENO EN RECEBO COMPACTADO B200 |  | 6d | 2026-04-22 | 2026-04-28 | 11 | 0d |  |
| 14 | 3.7 | ELEMENTOS URBANOS | milestone | 0d | 2026-03-25 | 2026-03-25 |  | 34d |  |
| 15 | 3.8 | BANCAS EN LADRILLO SEMI-PRENZADO CON DOBELAS EN CONCRETO, IMPERMEABILIZADAS 2x4 |  | 15d | 2026-04-27 | 2026-05-13 | 12 | 28d |  |
| 16 | 3.9 | SUMINISTRO E INSTALACIÓN DE CAMARAS DE CIBERSEGURIDAD CIRCUITO CERRADO INCLUIDO CONECTIVIDAD WIFI |  | 12d | 2026-03-26 | 2026-04-08 | 9 | 58d |  |
| 17 | 3.10 | PISOS Y ACABADOS ARQUITECTONICOS | milestone | 0d | 2026-03-25 | 2026-03-25 |  | 34d |  |
| 18 | 3.11 | CERRAMIENTO EN MALLA ESLABONADA CAL 10 (INCLUYE TUBO AGUA NEGRA DE 2" Y ANGULO 1" X 1" X 1/8") h=1.8 m |  | 25d | 2026-05-18 | 2026-06-15 | 19 | 0d |  |
| 19 | 3.12 | SUMINISTRO E INSTALACIÓN DE ADOQUÍN PARA EXTERIORES FORMATO 15X18, COLOR TERRACOTA. |  | 16d | 2026-04-29 | 2026-05-16 | 13 | 0d |  |
| 20 | 3.13 | INSTALACIONES ELECTRICAS Y DE DATOS | milestone | 0d | 2026-03-25 | 2026-03-25 |  | 34d |  |
| 21 | 3.14 | SUMINISTRO E INSTALACIÓN DE ELEMENTOS DE ACOMETIDA AÉREA. CONEXIÓN DESDE RED TRENZADA DE B.T., BAJANTE HACIA EQUIPO DE MEDIDA EN TUBO IMC DE 1". |  | 5d | 2026-05-18 | 2026-05-22 | 19 | 16d | 0d |
| 22 | 3.15 | SUMINISTRO E INSTALACION TOMA DOBLE INCLUYE APARATO NO INCLUYE CABLE |  | 3d | 2026-05-20 | 2026-05-22 | 21FS-3d | 16d | 0d |
| 23 | 3.16 | SUMINISTRO E INSTALACION LUMINARIA LINEAL LED COMERCIAL 40 W LUZ DIA NO INCLUYE CABLE |  | 4d | 2026-05-23 | 2026-05-27 | 22 | 16d |  |
| 24 | 3.17 | INSTALACIONES HIDROSANITARIAS Y GAS | milestone | 0d | 2026-03-25 | 2026-03-25 |  | 34d |  |
| 25 | 3.18 | PAGO ACOMETIDA DE ACUEDUCTO Y ALCANTARILLADO |  | 1d | 2026-04-27 | 2026-04-27 | 12 | 30d | 0d |
| 26 | 3.19 | SUMINISTRO E INSTALACION TUBERÍA HIDRÁULICA HIDRAULICO 1/2" DE DISTRIBUCIÓN |  | 6d | 2026-04-28 | 2026-05-04 | 25 | 36d |  |
| 27 | 3.20 | SUMINISTRO E INSTALACION TUBERÍA SANITARIA DE RECOLECCIÓN 3" |  | 4d | 2026-04-28 | 2026-05-01 | 25 | 38d |  |
| 28 | 3.21 | EXCAVACIÓN MANUAL EN MATERIAL COMÚN |  | 6d | 2026-04-28 | 2026-05-04 | 25 | 30d | 0d |
| 29 | 3.22 | RELLENO EN RECEBO COMPACTADO B200 |  | 5d | 2026-05-05 | 2026-05-09 | 28 | 31d |  |
| 30 | 3.23 | SUMINISTRO E INSTALACIÓN DE CUARTO PARA GAS |  | 6d | 2026-05-05 | 2026-05-11 | 28 | 30d |  |
| 31 | 3.24 | ASEO Y RETIRO DE ESCOMBROS | milestone | 0d | 2026-03-25 | 2026-03-25 |  | 34d |  |
| 32 | 3.25 | RETIRO DE ESCOMBROS |  | 2d | 2026-03-25 | 2026-03-26 |  | 54d |  |
| 33 | 3.26 | ASEO FINAL |  | 2d | 2026-03-25 | 2026-03-26 |  | 54d |  |

| ID | WBS | Task | Type | Duration | Start | Finish | Predecessors | Total slack | Free slack | Constraint |
| --- | --- | --- | --- | --- | --- | --- | --- | --- | --- | --- |
| 34 | 4 | **MODULO TIENDAS** |  | 49d | 2026-03-25 | 2026-05-20 | 2FS-10d | 22d |  |  |
| 35 | 4.1 | PRELIMINARES | milestone | 0d | 2026-03-25 | 2026-03-25 |  | 71d |  |  |
| 36 | 4.2 | LOCALIZACIÓN Y REPLANTEO |  | 2d | 2026-03-25 | 2026-03-26 |  | 22d | 0d |  |
| 37 | 4.3 | DEMOLICIÓN DE ANDÉN E > A 12 CM. (INCLUYE RETIRO Y ACARREO LIBRE HASTA 5 KM.) |  | 10d | 2026-03-27 | 2026-04-07 | 36 | 33d | 0d |  |
| 38 | 4.4 | EXCAVACIÓN MANUAL EN MATERIAL COMÚN |  | 10d | 2026-04-08 | 2026-04-18 | 37 | 33d | 0d |  |
| 39 | 4.5 | ESTRUCTURA EN CONCRETO | milestone | 0d | 2026-03-25 | 2026-03-25 |  | 71d |  |  |
| 40 | 4.6 | SUMINISTRO E INSTALACION DE DADOS EN CONCRETO SIMPLE DE 4000 PSIDE 30X30 CMS |  | 12d | 2026-04-20 | 2026-05-02 | 38 | 37d |  |  |
| 41 | 4.7 | CONCRETO SIMPLE DE 28 Mpa. (4000 PSI) |  | 8d | 2026-04-20 | 2026-04-28 | 38 | 33d | 0d |  |
| 42 | 4.8 | RELLENO EN RECEBO COMPACTADO B200 |  | 8d | 2026-04-29 | 2026-05-07 | 41 | 33d |  |  |
| 43 | 4.9 | ESTRUCTURA METALICA | milestone | 0d | 2026-03-25 | 2026-03-25 |  | 71d |  |  |
| 44 | 4.10 | SUMINISTRO, TRANSPORTE, FABRICACIÓN, FIGURADA Y/O ROLADO, ENSAMBLAJE Y MONTAJE MANUAL DE ESTRUCTURA METALICA |  | 20d | 2026-03-27 | 2026-04-18 | 36 | 22d | 0d |  |
| 45 | 4.11 | SUMINISTRO E INSTALACIÓN DE ESMALTE SINTÉTICO PARA ESTRUCTURA METALICA. (INCLUYE BASE EN ANTICORROSIVO). |  | 6d | 2026-04-20 | 2026-04-25 | 44 | 22d | 0d |  |
| 46 | 4.12 | SUMINISTRO E INSTALACION CUBIERTA EN PERFILERIA METALICA, TEJA UPVC COLOR SEGÚN DISEÑO ESPESOR 6 MM. |  | 10d | 2026-04-27 | 2026-05-07 | 45 | 22d | 0d |  |
| 47 | 4.13 | SUMINISTRO E INSTALACION DE CANAL EN LAMINA COLD ROLLED CAL. 20 D=0.75 CON PINTURA Y ANTICORROSIVO |  | 8d | 2026-04-27 | 2026-05-05 | 45 | 35d |  | start no earlier than 2026-03-02 |
| 48 | 4.14 | SUMINISTRO E INSTALACION LAMINA EN SUPERBOARD DE 10 MM |  | 8d | 2026-05-08 | 2026-05-16 | 46 | 22d | 0d |  |
| 49 | 4.15 | Suministro e instalación de lámina microperforada en acero galvanizado |  | 4d | 2026-05-08 | 2026-05-12 | 46 | 26d | 0d |  |
| 50 | 4.16 | SUMINISTRO E INSTALACIÓN DE MESÓN 60 CM ANCHO EN LÁMINA GALVANIZADA CALIBRE 22 CON SOPORTES Y ANGULOS A=45 CM, PINTURA ELECTROSTÁTICA |  | 3d | 2026-05-18 | 2026-05-20 | 48 | 22d |  |  |
| 51 | 4.17 | POCETA EN LADRILLO Y ENCHAPE DE 0.6 m * 0.4 m |  | 3d | 2026-05-13 | 2026-05-15 | 49 | 26d |  |  |
| 52 | 4.18 | INSTALACIONES ELECTRICAS | milestone | 0d | 2026-03-25 | 2026-03-25 |  | 71d |  |  |
| 53 | 4.19 | SUMINISTRO E INSTALACION SALIDA DE ILUMINACION |  | 3d | 2026-04-20 | 2026-04-22 | 44 | 43d | 0d |  |
| 54 | 4.20 | SUMINISTRO E INSTALACION PUNTO ELECTRICO INTERRUPTOR |  | 3d | 2026-04-23 | 2026-04-25 | 53 | 43d |  |  |
| 55 | 4.21 | SUMINISTRO E INSTALACION TOMA DOBLE INCLUYE APARATO |  | 3d | 2026-04-23 | 2026-04-25 | 53 | 43d |  |  |
| 56 | 4.22 | SUMINISTRO E INSTALACION LUMINARIA LINEAL LED COMERCIAL 40 W LUZ DIA |  | 3d | 2026-04-23 | 2026-04-25 | 53 | 43d |  |  |
| 57 | 4.23 | INSTALACIONES HIDROSANITARIAS E HIDRAULICAS | milestone | 0d | 2026-03-25 | 2026-03-25 |  | 71d |  |  |
| 58 | 4.24 | SUMINISTRO E INSTALACION LAVAPLATOS SENCILLO EN ACERO INOXIDABLE |  | 4d | 2026-04-27 | 2026-04-30 | 45 | 39d |  |  |
| 59 | 4.25 | SUMINISTRO E INSTALACION PUNTO HIDRAULICO 1/2" |  | 4d | 2026-04-27 | 2026-04-30 | 45 | 37d | 0d |  |
| 60 | 4.26 | ASEO Y RETIRO DE ESCOMBROS | milestone | 0d | 2026-03-25 | 2026-03-25 |  | 71d |  |  |
| 61 | 4.27 | RETIRO DE ESCOMBROS |  | 1d | 2026-05-01 | 2026-05-01 | 59 | 37d | 0d |  |
| 62 | 4.28 | ASEO FINAL |  | 1d | 2026-05-02 | 2026-05-02 | 61 | 37d |  |  |

| ID | WBS | Task | Type | Duration | Start | Finish | Predecessors | Total slack | Free slack |
| --- | --- | --- | --- | --- | --- | --- | --- | --- | --- |
| 63 | 5 | **MODULO BAÑOS** |  | 36d | 2026-03-25 | 2026-05-05 | 2FS-10d | 35d |  |
| 64 | 5.1 | PRELIMINARES | milestone | 0d | 2026-03-25 | 2026-03-25 |  | 71d |  |
| 65 | 5.2 | LOCALIZACIÓN Y REPLANTEO |  | 1d | 2026-03-25 | 2026-03-25 |  | 35d | 0d |
| 66 | 5.3 | DEMOLICIÓN DE ANDÉN E > A 12 CM. (INCLUYE RETIRO Y ACARREO LIBRE HASTA 5 KM.) |  | 4d | 2026-03-26 | 2026-03-30 | 65 | 55d | 0d |
| 67 | 5.4 | EXCAVACIÓN MANUAL EN MATERIAL COMÚN |  | 4d | 2026-03-31 | 2026-04-03 | 66 | 55d | 0d |
| 68 | 5.5 | ESTRUCTURA EN CONCRETO | milestone | 0d | 2026-03-25 | 2026-03-25 |  | 71d |  |
| 69 | 5.6 | PLATINAS ENVEVIDAS DE SOPORTE PARA COLUMNAS DE ACERO |  | 3d | 2026-04-04 | 2026-04-07 | 67 | 59d |  |
| 70 | 5.7 | CONCRETO SIMPLE DE 28 Mpa. (4000 PSI) |  | 4d | 2026-04-04 | 2026-04-08 | 67 | 55d | 0d |
| 71 | 5.8 | RELLENO EN RECEBO COMPACTADO B200 |  | 2d | 2026-04-09 | 2026-04-10 | 70 | 56d |  |
| 72 | 5.9 | POCETA EN LADRILLO Y ENCHAPE DE 0.6 m * 0.4 m |  | 3d | 2026-04-09 | 2026-04-11 | 70 | 55d |  |
| 73 | 5.10 | ESTRUCTURA METALICA | milestone | 0d | 2026-03-25 | 2026-03-25 |  | 71d |  |
| 74 | 5.11 | SUMINISTRO, TRANSPORTE, FABRICACIÓN, FIGURADA Y/O ROLADO, ENSAMBLAJE Y MONTAJE MANUAL DE ESTRUCTURA METALICA INCLUYE PEDESTAL |  | 15d | 2026-03-26 | 2026-04-11 | 65 | 35d | 0d |
| 75 | 5.12 | SUMINISTRO E INSTALACIÓN DE ESMALTE SINTÉTICO PARA ESTRUCTURA METALICA. (INCLUYE BASE EN ANTICORROSIVO). |  | 4d | 2026-04-13 | 2026-04-16 | 74 | 35d | 0d |
| 76 | 5.13 | SUMINISTRO E INSTALACION CUBIERTA EN PERFILERIA METALICA, TEJA UPVC COLOR SEGÚN DISEÑO |  | 6d | 2026-04-17 | 2026-04-23 | 75 | 35d | 0d |
| 77 | 5.14 | SUMINISTRO E INSTALACION DE CANAL EN LAMINA COLD ROLLED CAL. 20 D=0.75 CON PINTURA Y ANTICORROSIVO |  | 4d | 2026-04-24 | 2026-04-28 | 76 | 35d | 0d |
| 78 | 5.15 | SUMINISTRO E INSTALACION LAMINA EN SUPERBOARD DE 10 MM |  | 4d | 2026-04-29 | 2026-05-02 | 77 | 35d | 0d |
| 79 | 5.16 | SUMINISTRO E INSTALACION PISO CERÁMICA BLANCO 50X50 |  | 4d | 2026-04-29 | 2026-05-02 | 77 | 37d |  |
| 80 | 5.17 | REJILLA DE VENTILACION 20X50 CM |  | 2d | 2026-05-04 | 2026-05-05 | 78 | 35d |  |
| 81 | 5.18 | Camerino individual para cambio de ropa, con estructura metálica, puerta metálica con cerradura, banco interior y accesorios. Incluye materiales, mano de obra 1.20*1.20 m |  | 6d | 2026-04-29 | 2026-05-05 | 77 | 35d |  |
| 82 | 5.19 | INSTALACIONES ELECTRICAS | milestone | 0d | 2026-03-25 | 2026-03-25 |  | 71d |  |
| 83 | 5.20 | SUMINISTRO E INSTALACION SALIDA DE ILUMINACION |  | 3d | 2026-04-13 | 2026-04-15 | 74 | 43d | 0d |
| 84 | 5.21 | SUMINISTRO E INSTALACION PUNTO ELECTRICO INTERRUPTOR |  | 3d | 2026-04-16 | 2026-04-18 | 83 | 43d | 0d |
| 85 | 5.22 | SUMINISTRO E INSTALACION TOMA DOBLE INCLUYE APARATO |  | 3d | 2026-04-20 | 2026-04-22 | 84 | 43d | 0d |
| 86 | 5.23 | SUMINISTRO E INSTALACION LUMINARIA LINEAL LED COMERCIAL 40 W LUZ DIA |  | 3d | 2026-04-23 | 2026-04-25 | 85 | 43d |  |
| 87 | 5.24 | INSTALACIONES HIDROSANITARIAS E HIDRAULICAS | milestone | 0d | 2026-03-25 | 2026-03-25 |  | 71d |  |
| 88 | 5.25 | SUMINISTRO E INSTALACION DE SANITARIO AHORRADOR CON ACOPLE |  | 3d | 2026-04-13 | 2026-04-15 | 74 | 40d | 0d |
| 89 | 5.26 | SUMINISTRO E INSTALACIÓN DE ORINAL INFANTIL LINEA INSTITUCIONAL. (INCLUYE ACCESORIOS) |  | 3d | 2026-04-16 | 2026-04-18 | 88 | 40d | 0d |
| 90 | 5.27 | SUMINISTRO E INSTALACION DE INCRUSTACIONES Y ESPEJO PARA BAÑO |  | 3d | 2026-04-20 | 2026-04-22 | 89 | 40d | 0d |
| 91 | 5.28 | SUMINISTRO E INSTALACION PUNTO HIDRAULICO 1/2" |  | 4d | 2026-04-23 | 2026-04-27 | 90 | 40d | 0d |
| 92 | 5.29 | SUMINISTRO E INSTALACION LAVAMANOS SENCILLO CON ACOPLE |  | 2d | 2026-04-23 | 2026-04-24 | 90 | 44d |  |
| 93 | 5.30 | ASEO Y RETIRO DE ESCOMBROS | milestone | 0d | 2026-03-25 | 2026-03-25 |  | 71d |  |
| 94 | 5.31 | RETIRO DE ESCOMBROS |  | 1d | 2026-04-28 | 2026-04-28 | 91 | 40d | 0d |
| 95 | 5.32 | ASEO FINAL |  | 1d | 2026-04-29 | 2026-04-29 | 94 | 40d |  |
| 96 | 6 | FIN | milestone | 0d | 2026-03-02 | 2026-03-02 | 1 | 54d |  |
