# BP PUENTE PEATONAL SALITRE EL GRECO

Schedule from MS Project, 2026-03-02 to 2026-06-16.

## Calendars

- BP BOGOTA: Mon-Sat 08:00-12:00, 13:00-17:00; Sun off.

## Schedule

| ID | WBS | Task | Type | Duration | Start | Finish | Predecessors | Total slack | Free slack |
| --- | --- | --- | --- | --- | --- | --- | --- | --- | --- |
| 1 | 1 | INCIO | milestone | 0d | 2026-03-02 | 2026-03-02 |  | 5d | 0d |
| 2 | 2 | **ACTIVIDADES DE GESTION AMERICAS CON 26** |  | 30d | 2026-03-02 | 2026-04-04 | 1 |  |  |
| 3 | 2.1 | TRAMITE ADMISTRATIVO |  | 10d | 2026-03-02 | 2026-03-12 |  | 5d | 0d |
| 4 | 2.2 | TRAMITE LEGAL |  | 10d | 2026-03-13 | 2026-03-24 | 3, 6 | 5d | 0d |
| 5 | 2.3 | AUTORIZACION AUTOMATICA |  | 5d | 2026-03-25 | 2026-03-30 | 4, 6 | 5d |  |
| 6 | 2.4 | AUTORIZACION LEGAL |  | 5d | 2026-03-02 | 2026-03-06 |  | 5d |  |
| 7 | 3 | **URBANISMO** |  | 72d | 2026-03-25 | 2026-06-16 | 2FS-10d | 0d |  |
| 8 | 3.1 | PRELIMINARES | milestone | 0d | 2026-03-25 | 2026-03-25 |  | 72d |  |
| 9 | 3.2 | LOCALIZACIÓN Y REPLANTEO OBRA ARQUITECTÓNICA |  | 2d | 2026-03-25 | 2026-03-26 |  | 0d |  |
| 10 | 3.3 | CERRAMIENTO EN VARA ROLLIZA Y LONA H=1.50 M . DISTANCIA ENTRE POSTES 2 M |  | 10d | 2026-03-27 | 2026-04-07 | 9 | 0d |  |
| 11 | 3.4 | DEMOLICIÓN DE ANDÉN E > A 12 CM. (INCLUYE RETIRO Y ACARREO LIBRE HASTA 5 KM.) |  | 3d | 2026-04-08 | 2026-04-10 | 10 | 0d |  |
| 12 | 3.5 | DEMOLICIÓN DE PIEDRA CANTERA (INCLUYE RETIRO Y ACARREO LIBRE HASTA 5 KM.) |  | 15d | 2026-04-11 | 2026-04-28 | 11 | 0d |  |
| 13 | 3.6 | EXCAVACIÓN MANUAL EN MATERIAL COMÚN |  | 10d | 2026-04-29 | 2026-05-09 | 12 | 0d |  |
| 14 | 3.7 | RELLENO EN RECEBO COMPACTADO B200 |  | 8d | 2026-05-11 | 2026-05-19 | 13 | 0d |  |
| 15 | 3.8 | ELEMENTOS URBANOS | milestone | 0d | 2026-03-25 | 2026-03-25 |  | 72d | 0d |
| 16 | 3.9 | SUMINISTRO E INSTALACIÓN DE CAMARAS DE CIBERSEGURIDAD CIRCUITO CERRADO INCLUIDO CONECTIVIDAD WIFI |  | 12d | 2026-03-27 | 2026-04-09 | 9 | 48d | 0d |
| 17 | 3.10 | BANCAS EN LADRILLO SEMI-PRENZADO CON DOBELAS EN CONCRETO, IMPERMEABILIZADAS 2x4 |  | 15d | 2026-04-17 | 2026-05-04 | 19 | 37d |  |
| 18 | 3.11 | PISOS Y ACABADOS ARQUITECTONICOS | milestone | 0d | 2026-03-25 | 2026-03-25 |  | 72d |  |
| 19 | 3.12 | SUMINISTRO E INSTALACIÓN DE ADOQUÍN PARA EXTERIORES FORMATO 15X18, COLOR TERRACOTA. |  | 20d | 2026-03-25 | 2026-04-16 |  | 37d | 0d |
| 20 | 3.13 | INSTALACIONES ELECTRICAS Y DE DATOS | milestone | 0d | 2026-03-25 | 2026-03-25 | 15 | 72d |  |
| 21 | 3.14 | SUMINISTRO E INSTALACIÓN DE ELEMENTOS DE ACOMETIDA AÉREA. CONEXIÓN DESDE RED TRENZADA DE B.T., BAJANTE HACIA EQUIPO DE MEDIDA EN TUBO IMC DE 1". 15 mts |  | 6d | 2026-04-10 | 2026-04-16 | 16 | 48d | 20d |
| 22 | 3.15 | SUMINISTRO E TENDIDO DE CABLE UTP CATEGORÍA 6A |  | 3d | 2026-05-18 | 2026-05-20 | 21, 23 | 23d |  |
| 23 | 3.16 | SUMINISTRO E INSTALACION DE PUNTO DE INTERNET NO INCLUYE CABLE |  | 6d | 2026-05-11 | 2026-05-16 | 13 | 23d | 0d |
| 24 | 3.17 | SUMINISTRO, INSTALACIÓN Y CONEXIONADO DE CABLE CONCENTRICO (ANTIFRAUDE) No. 2 x 6 +6 AWG EN COBRE PARA ACOMETIDA BIFÁSICA |  | 4d | 2026-05-11 | 2026-05-14 | 13, 21 | 28d |  |
| 25 | 3.18 | INSTALACIONES HIDROSANITARIAS Y GAS | milestone | 0d | 2026-03-25 | 2026-03-25 |  | 72d |  |
| 26 | 3.19 | PAGO ACOMETIDA DE ACUEDUCTO Y ALCANTARILLADO |  | 3d | 2026-05-18 | 2026-05-20 | 23 | 23d |  |
| 27 | 3.20 | SUMINISTRO E INSTALACION TUBERÍA HIDRÁULICA HIDRAULICO 1/2" DE DISTRIBUCIÓN |  | 6d | 2026-05-27 | 2026-06-02 | 9, 29 | 0d |  |
| 28 | 3.21 | SUMINISTRO E INSTALACION TUBERÍA SANITARIA DE RECOLECCIÓN 6" |  | 8d | 2026-06-03 | 2026-06-11 | 27 | 0d |  |
| 29 | 3.22 | EXCAVACIÓN MANUAL EN MATERIAL COMÚN |  | 6d | 2026-05-20 | 2026-05-26 | 14 | 0d |  |
| 30 | 3.23 | RELLENO EN RECEBO COMPACTADO B200 |  | 4d | 2026-06-12 | 2026-06-16 | 28 | 0d |  |
| 31 | 3.24 | SUMINISTRO E INSTALACIÓN DE CUARTO PARA GAS |  | 12d | 2026-05-27 | 2026-06-09 | 29 | 2d | 0d |
| 32 | 3.25 | ASEO Y RETIRO DE ESCOMBROS | milestone | 0d | 2026-03-25 | 2026-03-25 |  | 72d |  |
| 33 | 3.26 | RETIRO DE ESCOMBROS |  | 2d | 2026-06-10 | 2026-06-11 | 31 | 2d | 0d |
| 34 | 3.27 | ASEO FINAL |  | 2d | 2026-06-12 | 2026-06-13 | 33 | 2d |  |

| ID | WBS | Task | Type | Duration | Start | Finish | Predecessors | Total slack | Free slack | Constraint |
| --- | --- | --- | --- | --- | --- | --- | --- | --- | --- | --- |
| 35 | 4 | **MODULO TIENDAS** |  | 52d | 2026-03-25 | 2026-05-23 | 2FS-10d | 20d |  |  |
| 36 | 4.1 | PRELIMINARES | milestone | 0d | 2026-03-25 | 2026-03-25 |  | 72d |  |  |
| 37 | 4.2 | LOCALIZACIÓN Y REPLANTEO |  | 2d | 2026-03-27 | 2026-03-28 | 9 | 20d | 0d |  |
| 38 | 4.3 | DEMOLICIÓN DE ANDÉN E > A 12 CM. (INCLUYE RETIRO Y ACARREO LIBRE HASTA 5 KM.) |  | 10d | 2026-03-30 | 2026-04-09 | 37 | 20d | 0d |  |
| 39 | 4.4 | EXCAVACIÓN MANUAL EN MATERIAL COMÚN |  | 10d | 2026-04-10 | 2026-04-21 | 38 | 20d | 0d |  |
| 40 | 4.5 | ESTRUCTURA EN CONCRETO | milestone | 0d | 2026-03-25 | 2026-03-25 |  | 72d |  |  |
| 41 | 4.6 | SUMINISTRO E INSTALACION DE DADOS EN CONCRETO SIMPLE DE 4000 PSIDE 30X30 CMS |  | 12d | 2026-04-22 | 2026-05-05 | 39 | 20d | 0d |  |
| 42 | 4.7 | CONCRETO SIMPLE DE 28 Mpa. (4000 PSI) |  | 8d | 2026-05-06 | 2026-05-14 | 41 | 20d | 0d |  |
| 43 | 4.8 | RELLENO EN RECEBO COMPACTADO B200 |  | 8d | 2026-05-15 | 2026-05-23 | 42 | 20d |  |  |
| 44 | 4.9 | ESTRUCTURA METALICA | milestone | 0d | 2026-03-25 | 2026-03-25 |  | 72d |  |  |
| 45 | 4.10 | SUMINISTRO, TRANSPORTE, FABRICACIÓN, FIGURADA Y/O ROLADO, ENSAMBLAJE Y MONTAJE MANUAL DE ESTRUCTURA METALICA |  | 25d | 2026-03-30 | 2026-04-27 | 37 | 21d | 0d |  |
| 46 | 4.11 | SUMINISTRO E INSTALACIÓN DE ESMALTE SINTÉTICO PARA ESTRUCTURA METALICA. (INCLUYE BASE EN ANTICORROSIVO). |  | 8d | 2026-04-28 | 2026-05-06 | 45 | 35d |  |  |
| 47 | 4.12 | SUMINISTRO E INSTALACION CUBIERTA EN PERFILERIA METALICA, TEJA UPVC COLOR SEGÚN DISEÑO ESPESOR 6 MM. |  | 12d | 2026-04-28 | 2026-05-11 | 45 | 21d | 0d |  |
| 48 | 4.13 | SUMINISTRO E INSTALACION DE CANAL EN LAMINA COLD ROLLED CAL. 20 D=0.75 CON PINTURA Y ANTICORROSIVO |  | 10d | 2026-05-12 | 2026-05-22 | 47 | 21d |  | start no earlier than 2026-03-02 |
| 49 | 4.14 | SUMINISTRO E INSTALACION LAMINA EN SUPERBOARD DE 10 MM |  | 10d | 2026-04-28 | 2026-05-08 | 45 | 33d |  |  |
| 50 | 4.15 | Suministro e instalación de lámina microperforada en acero galvanizado |  | 4d | 2026-04-28 | 2026-05-01 | 45 | 33d | 0d |  |
| 51 | 4.16 | SUMINISTRO E INSTALACIÓN DE MESÓN 60 CM ANCHO EN LÁMINA GALVANIZADA CALIBRE 22 CON SOPORTES Y ANGULOS A=45 CM, PINTURA ELECTROSTÁTICA |  | 3d | 2026-05-02 | 2026-05-05 | 50 | 33d | 0d |  |
| 52 | 4.17 | POCETA EN LADRILLO Y ENCHAPE DE 0.6 m * 0.4 m |  | 3d | 2026-05-06 | 2026-05-08 | 51 | 33d |  |  |
| 53 | 4.18 | INSTALACIONES ELECTRICAS | milestone | 0d | 2026-03-25 | 2026-03-25 |  | 72d |  |  |
| 54 | 4.19 | SUMINISTRO E INSTALACION SALIDA DE ILUMINACION |  | 3d | 2026-04-28 | 2026-04-30 | 45 | 36d | 0d |  |
| 55 | 4.20 | SUMINISTRO E INSTALACION PUNTO ELECTRICO INTERRUPTOR |  | 3d | 2026-05-01 | 2026-05-04 | 54 | 37d |  |  |
| 56 | 4.21 | SUMINISTRO E INSTALACION TOMA DOBLE INCLUYE APARATO |  | 3d | 2026-05-01 | 2026-05-04 | 54 | 37d |  |  |
| 57 | 4.22 | SUMINISTRO E INSTALACION LUMINARIA LINEAL LED COMERCIAL 40 W LUZ DIA |  | 4d | 2026-05-01 | 2026-05-05 | 54 | 36d |  |  |
| 58 | 4.23 | INSTALACIONES HIDROSANITARIAS E HIDRAULICAS | milestone | 0d | 2026-03-25 | 2026-03-25 |  | 72d |  |  |
| 59 | 4.24 | SUMINISTRO E INSTALACION LAVAPLATOS SENCILLO EN ACERO INOXIDABLE |  | 4d | 2026-04-28 | 2026-05-01 | 45 | 35d | 0d |  |
| 60 | 4.25 | SUMINISTRO E INSTALACION PUNTO HIDRAULICO 1/2" |  | 4d | 2026-05-02 | 2026-05-06 | 59 | 35d |  |  |
| 61 | 4.26 | ASEO Y RETIRO DE ESCOMBROS | milestone | 0d | 2026-03-25 | 2026-03-25 |  | 72d |  |  |
| 62 | 4.27 | RETIRO DE ESCOMBROS |  | 2d | 2026-05-02 | 2026-05-04 | 59 | 35d | 0d |  |
| 63 | 4.28 | ASEO FINAL |  | 2d | 2026-05-05 | 2026-05-06 | 62 | 35d |  |  |

| ID | WBS | Task | Type | Duration | Start | Finish | Predecessors | Total slack | Free slack |
| --- | --- | --- | --- | --- | --- | --- | --- | --- | --- |
| 64 | 5 | **MODULO BAÑOS** |  | 34d | 2026-03-25 | 2026-05-02 | 2FS-10d | 38d |  |
| 65 | 5.1 | PRELIMINARES | milestone | 0d | 2026-03-25 | 2026-03-25 |  | 72d |  |
| 66 | 5.2 | LOCALIZACIÓN Y REPLANTEO |  | 1d | 2026-03-25 | 2026-03-25 |  | 38d | 0d |
| 67 | 5.3 | DEMOLICIÓN DE ANDÉN E > A 12 CM. (INCLUYE RETIRO Y ACARREO LIBRE HASTA 5 KM.) |  | 4d | 2026-03-26 | 2026-03-30 | 66 | 54d | 0d |
| 68 | 5.4 | EXCAVACIÓN MANUAL EN MATERIAL COMÚN |  | 4d | 2026-03-31 | 2026-04-03 | 67 | 54d | 0d |
| 69 | 5.5 | ESTRUCTURA EN CONCRETO | milestone | 0d | 2026-03-25 | 2026-03-25 |  | 72d |  |
| 70 | 5.6 | PLATINAS ENVEVIDAS DE SOPORTE PARA COLUMNAS DE ACERO |  | 3d | 2026-04-04 | 2026-04-07 | 68 | 60d |  |
| 71 | 5.7 | CONCRETO SIMPLE DE 28 Mpa. (4000 PSI) |  | 4d | 2026-04-04 | 2026-04-08 | 68 | 54d | 0d |
| 72 | 5.8 | RELLENO EN RECEBO COMPACTADO B200 |  | 2d | 2026-04-09 | 2026-04-10 | 71 | 54d | 0d |
| 73 | 5.9 | POCETA EN LADRILLO Y ENCHAPE DE 0.6 m * 0.4 m |  | 3d | 2026-04-11 | 2026-04-14 | 72 | 54d |  |
| 74 | 5.10 | ESTRUCTURA METALICA | milestone | 0d | 2026-03-25 | 2026-03-25 |  | 72d |  |
| 75 | 5.11 | SUMINISTRO, TRANSPORTE, FABRICACIÓN, FIGURADA Y/O ROLADO, ENSAMBLAJE Y MONTAJE MANUAL DE ESTRUCTURA METALICA INCLUYE PEDESTAL |  | 15d | 2026-03-26 | 2026-04-11 | 66 | 38d | 0d |
| 76 | 5.12 | SUMINISTRO E INSTALACIÓN DE ESMALTE SINTÉTICO PARA ESTRUCTURA METALICA. (INCLUYE BASE EN ANTICORROSIVO). |  | 4d | 2026-04-13 | 2026-04-16 | 75 | 38d | 0d |
| 77 | 5.13 | SUMINISTRO E INSTALACION CUBIERTA EN PERFILERIA METALICA, TEJA UPVC COLOR SEGÚN DISEÑO |  | 6d | 2026-04-17 | 2026-04-23 | 76 | 38d | 0d |
| 78 | 5.14 | SUMINISTRO E INSTALACION DE CANAL EN LAMINA COLD ROLLED CAL. 20 D=0.75 CON PINTURA Y ANTICORROSIVO |  | 4d | 2026-04-24 | 2026-04-28 | 77 | 38d | 0d |
| 79 | 5.15 | SUMINISTRO E INSTALACION LAMINA EN SUPERBOARD DE 10 MM |  | 4d | 2026-04-29 | 2026-05-02 | 78 | 38d |  |
| 80 | 5.16 | SUMINISTRO E INSTALACION PISO CERÁMICA BLANCO 50X50 |  | 4d | 2026-04-29 | 2026-05-02 | 78 | 38d |  |
| 81 | 5.17 | REJILLA DE VENTILACION 20X50 CM |  | 2d | 2026-04-29 | 2026-04-30 | 78 | 40d |  |
| 82 | 5.18 | Camerino individual para cambio de ropa, con estructura metálica, puerta metálica con cerradura, banco interior y accesorios. Incluye materiales, mano de obra 1.20*1.20 m |  | 6d | 2026-04-13 | 2026-04-18 | 75 | 50d |  |
| 83 | 5.19 | INSTALACIONES ELECTRICAS | milestone | 0d | 2026-03-25 | 2026-03-25 |  | 72d |  |
| 84 | 5.20 | SUMINISTRO E INSTALACION SALIDA DE ILUMINACION |  | 3d | 2026-04-13 | 2026-04-15 | 75 | 50d | 0d |
| 85 | 5.21 | SUMINISTRO E INSTALACION PUNTO ELECTRICO INTERRUPTOR |  | 3d | 2026-04-16 | 2026-04-18 | 84 | 50d |  |
| 86 | 5.22 | SUMINISTRO E INSTALACION TOMA DOBLE INCLUYE APARATO |  | 3d | 2026-04-16 | 2026-04-18 | 84 | 50d |  |
| 87 | 5.23 | SUMINISTRO E INSTALACION LUMINARIA LINEAL LED COMERCIAL 40 W LUZ DIA |  | 3d | 2026-04-16 | 2026-04-18 | 84 | 50d |  |
| 88 | 5.24 | INSTALACIONES HIDROSANITARIAS E HIDRAULICAS | milestone | 0d | 2026-03-25 | 2026-03-25 |  | 72d |  |
| 89 | 5.25 | SUMINISTRO E INSTALACION DE SANITARIO AHORRADOR CON ACOPLE |  | 3d | 2026-04-13 | 2026-04-15 | 75 | 47d | 0d |
| 90 | 5.26 | SUMINISTRO E INSTALACIÓN DE ORINAL INFANTIL LINEA INSTITUCIONAL. (INCLUYE ACCESORIOS) |  | 3d | 2026-04-16 | 2026-04-18 | 89 | 47d | 0d |
| 91 | 5.27 | SUMINISTRO E INSTALACION DE INCRUSTACIONES Y ESPEJO PARA BAÑO |  | 3d | 2026-04-20 | 2026-04-22 | 90 | 47d |  |
| 92 | 5.28 | SUMINISTRO E INSTALACION PUNTO HIDRAULICO 1/2" |  | 4d | 2026-04-16 | 2026-04-20 | 75, 89 | 49d |  |
| 93 | 5.29 | SUMINISTRO E INSTALACION LAVAMANOS SENCILLO CON ACOPLE |  | 2d | 2026-04-16 | 2026-04-17 | 89 | 51d |  |
| 94 | 5.30 | ASEO Y RETIRO DE ESCOMBROS | milestone | 0d | 2026-03-25 | 2026-03-25 |  | 72d |  |
| 95 | 5.31 | RETIRO DE ESCOMBROS |  | 2d | 2026-04-16 | 2026-04-17 | 89 | 50d | 0d |
| 96 | 5.32 | ASEO FINAL |  | 2d | 2026-04-17 | 2026-04-18 | 95FS-1d | 50d |  |
| 97 | 6 | FIN | milestone | 0d | 2026-03-02 | 2026-03-02 | 1 | 40d |  |
