# BP CALLE 63 CON 30

Schedule from MS Project, 2026-03-02 to 2026-07-29.

## Calendars

- BP BOGOTA: Mon-Sat 08:00-12:00, 13:00-17:00; Sun off.

## Schedule

| ID | WBS | Task | Type | Duration | Start | Finish | Predecessors | Total slack | Free slack |
| --- | --- | --- | --- | --- | --- | --- | --- | --- | --- |
| 1 | 1 | INCIO | milestone | 0d | 2026-03-02 | 2026-03-02 |  | 5d | 0d |
| 2 | 2 | **ACTIVIDADES DE GESTION AMERICAS CON 26** |  | 30d | 2026-03-02 | 2026-04-04 | 1 |  |  |
| 3 | 2.1 | TRAMITE ADMISTRATIVO |  | 10d | 2026-03-02 | 2026-03-12 |  | 5d | 0d |
| 4 | 2.2 | TRAMITE LEGAL |  | 10d | 2026-03-13 | 2026-03-24 | 3 | 5d | 0d |
| 5 | 2.3 | AUTORIZACION AUTOMATICA |  | 5d | 2026-03-13 | 2026-03-18 | 3 | 15d |  |
| 6 | 2.4 | AUTORIZACION LEGAL |  | 5d | 2026-03-25 | 2026-03-30 | 4 | 5d |  |
| 7 | 3 | **URBANISMO** |  | 61d | 2026-04-04 | 2026-06-15 | 2 | 0d |  |
| 8 | 3.1 | PRELIMINARES | milestone | 0d | 2026-04-04 | 2026-04-04 |  | 61d |  |
| 9 | 3.2 | LOCALIZACIÓN Y REPLANTEO OBRA ARQUITECTÓNICA |  | 3d | 2026-04-06 | 2026-04-08 |  | 0d |  |
| 10 | 3.3 | CERRAMIENTO EN VARA ROLLIZA Y LONA H=1.50 M . DISTANCIA ENTRE POSTES 2 M |  | 12d | 2026-04-09 | 2026-04-22 | 9 | 0d |  |
| 11 | 3.4 | EXCAVACIÓN MANUAL EN MATERIAL COMÚN PARA INSTALACIONES |  | 10d | 2026-04-23 | 2026-05-04 | 10 | 0d |  |
| 12 | 3.5 | RELLENO EN RECEBO COMPACTADO B200 |  | 8d | 2026-05-05 | 2026-05-13 | 11 | 0d |  |
| 13 | 3.6 | ESPACIOS DEPORTIVOS | milestone | 0d | 2026-04-04 | 2026-04-04 |  | 61d |  |
| 14 | 3.7 | PARQUE PARA NIÑOS ESTANDAR (CULUMPIOS, RODADERO, CON CERRAMIENTO EN MALLA CON ESTRUCTURA), PISO GOMA |  | 20d | 2026-05-14 | 2026-06-05 | 12 | 8d |  |
| 15 | 3.8 | ELEMENTOS URBANOS | milestone | 0d | 2026-04-04 | 2026-04-04 |  | 61d |  |
| 16 | 3.9 | CERRAMIENTO EN MALLA ESLABONADA CAL 10 (INCLUYE TUBO AGUA NEGRA DE 2" Y ANGULO 1" X 1" X 1/8" |  | 28d | 2026-05-14 | 2026-06-15 | 12 | 0d |  |
| 17 | 3.10 | BANCAS EN LADRILLO SEMI-PRENZADO CON DOBELAS EN CONCRETO, IMPERMEABILIZADAS 2x4 |  | 15d | 2026-05-14 | 2026-05-30 | 12 | 13d |  |
| 18 | 3.11 | PISOS Y ACABADOS ARQUITECTONICOS | milestone | 0d | 2026-04-04 | 2026-04-04 |  | 61d |  |
| 19 | 3.12 | SUMINISTRO E INSTALACIÓN DE ADOQUÍN PARA EXTERIORES FORMATO 15X18, COLOR TERRACOTA. |  | 18d | 2026-05-14 | 2026-06-03 | 12 | 3d | 0d |
| 20 | 3.13 | INSTALACIONES ELECTRICAS Y DE DATOS | milestone | 0d | 2026-04-04 | 2026-04-04 |  | 61d |  |
| 21 | 3.14 | SUMINISTRO E INSTALACIÓN DE ELEMENTOS DE ACOMETIDA AÉREA. CONEXIÓN DESDE RED TRENZADA DE B.T., BAJANTE HACIA EQUIPO DE MEDIDA EN TUBO IMC DE 1". 15 MTS |  | 4d | 2026-06-04 | 2026-06-08 | 19 | 3d | 0d |
| 22 | 3.15 | SUMINISTRO, INSTALACIÓN Y CONEXIONADO DE CABLE CONCENTRICO (ANTIFRAUDE) No. 2 x 6 +6 AWG EN COBRE PARA ACOMETIDA BIFÁSICA |  | 2d | 2026-06-09 | 2026-06-10 | 21 | 4d |  |
| 23 | 3.16 | SUMINISTRO E INSTALACION DE PUNTO DE INTERNET NO INCLUYE CABLE |  | 3d | 2026-06-09 | 2026-06-11 | 21 | 3d |  |
| 24 | 3.17 | INSTALACIONES HIDROSANITARIAS Y GAS | milestone | 0d | 2026-04-04 | 2026-04-04 |  | 61d |  |
| 25 | 3.18 | PAGO ACOMETIDA DE ACUEDUCTO Y ALCANTARILLADO |  | 1d | 2026-05-14 | 2026-05-14 | 12 | 18d | 0d |
| 26 | 3.19 | SUMINISTRO E INSTALACION TUBERÍA HIDRÁULICA HIDRAULICO 1/2" DE DISTRIBUCIÓN |  | 1d | 2026-05-15 | 2026-05-15 | 25 | 24d | 0d |
| 27 | 3.20 | SUMINISTRO E INSTALACION TUBERÍA SANITARIA DE RECOLECCIÓN 3" |  | 2d | 2026-05-16 | 2026-05-18 | 26 | 24d |  |
| 28 | 3.21 | SUMINISTRO E INSTALACIÓN TUBERÍA DE ALCANTARILLADO PVC D= 6" |  | 3d | 2026-05-15 | 2026-05-18 | 25 | 24d |  |
| 29 | 3.22 | EXCAVACIÓN MANUAL EN MATERIAL COMÚN |  | 5d | 2026-05-15 | 2026-05-20 | 25 | 18d | 0d |
| 30 | 3.23 | RELLENO EN RECEBO COMPACTADO B200 |  | 2d | 2026-05-21 | 2026-05-22 | 29 | 18d | 0d |
| 31 | 3.24 | ASEO Y RETIRO DE ESCOMBROS | milestone | 0d | 2026-04-04 | 2026-04-04 |  | 61d |  |
| 32 | 3.25 | RETIRO DE ESCOMBROS |  | 1d | 2026-05-23 | 2026-05-23 | 30 | 18d | 0d |
| 33 | 3.26 | ASEO FINAL |  | 1d | 2026-05-25 | 2026-05-25 | 32 | 18d |  |

| ID | WBS | Task | Type | Duration | Start | Finish | Predecessors | Total slack | Free slack | Constraint |
| --- | --- | --- | --- | --- | --- | --- | --- | --- | --- | --- |
| 34 | 4 | **MODULO TIENDAS** |  | 35d | 2026-06-15 | 2026-07-25 | 7 | 3d |  |  |
| 35 | 4.1 | PRELIMINARES | milestone | 0d | 2026-06-15 | 2026-06-15 |  | 38d |  |  |
| 36 | 4.2 | LOCALIZACIÓN Y REPLANTEO |  | 1d | 2026-06-16 | 2026-06-16 |  | 3d | 0d |  |
| 37 | 4.3 | DEMOLICIÓN DE ANDÉN E > A 12 CM. (INCLUYE RETIRO Y ACARREO LIBRE HASTA 5 KM.) |  | 8d | 2026-06-17 | 2026-06-25 | 36 | 3d | 0d |  |
| 38 | 4.4 | EXCAVACIÓN MANUAL EN MATERIAL COMÚN |  | 6d | 2026-06-26 | 2026-07-02 | 37 | 3d | 0d |  |
| 39 | 4.5 | ESTRUCTURA EN CONCRETO | milestone | 0d | 2026-06-15 | 2026-06-15 |  | 38d |  |  |
| 40 | 4.6 | SUMINISTRO E INSTALACION DE DADOS EN CONCRETO SIMPLE DE 4000 PSIDE 30X30 CMS |  | 6d | 2026-07-03 | 2026-07-09 | 38 | 3d | 0d |  |
| 41 | 4.7 | CONCRETO SIMPLE DE 28 Mpa. (4000 PSI) |  | 8d | 2026-07-10 | 2026-07-18 | 40 | 3d | 0d |  |
| 42 | 4.8 | RELLENO EN RECEBO COMPACTADO B200 |  | 6d | 2026-07-20 | 2026-07-25 | 41 | 3d |  |  |
| 43 | 4.9 | ESTRUCTURA METALICA | milestone | 0d | 2026-06-15 | 2026-06-15 |  | 38d |  |  |
| 44 | 4.10 | SUMINISTRO, TRANSPORTE, FABRICACIÓN, FIGURADA Y/O ROLADO, ENSAMBLAJE Y MONTAJE MANUAL DE ESTRUCTURA METALICA |  | 15d | 2026-06-17 | 2026-07-03 | 36 | 8d | 0d |  |
| 45 | 4.11 | SUMINISTRO E INSTALACIÓN DE ESMALTE SINTÉTICO PARA ESTRUCTURA METALICA. (INCLUYE BASE EN ANTICORROSIVO). |  | 6d | 2026-07-04 | 2026-07-10 | 44 | 16d |  |  |
| 46 | 4.12 | SUMINISTRO E INSTALACION CUBIERTA EN PERFILERIA METALICA, TEJA UPVC COLOR SEGÚN DISEÑO ESPESOR 6 MM. |  | 5d | 2026-07-04 | 2026-07-09 | 44 | 13d | 0d |  |
| 47 | 4.13 | SUMINISTRO E INSTALACION DE CANAL EN LAMINA COLD ROLLED CAL. 20 D=0.75 CON PINTURA Y ANTICORROSIVO |  | 4d | 2026-07-10 | 2026-07-14 | 46 | 13d |  | start no earlier than 2026-03-02 |
| 48 | 4.14 | SUMINISTRO E INSTALACION LAMINA EN SUPERBOARD DE 10 MM |  | 6d | 2026-07-04 | 2026-07-10 | 44 | 16d |  |  |
| 49 | 4.15 | Suministro e instalación de lámina microperforada en acero galvanizado |  | 5d | 2026-07-04 | 2026-07-09 | 44 | 8d | 0d |  |
| 50 | 4.16 | SUMINISTRO E INSTALACIÓN DE MESÓN 60 CM ANCHO EN LÁMINA GALVANIZADA CALIBRE 22 CON SOPORTES Y ANGULOS A=45 CM, PINTURA ELECTROSTÁTICA |  | 4d | 2026-07-10 | 2026-07-14 | 49 | 8d | 0d |  |
| 51 | 4.17 | POCETA EN LADRILLO Y ENCHAPE DE 0.6 m * 0.4 m |  | 5d | 2026-07-15 | 2026-07-20 | 50 | 8d |  |  |
| 52 | 4.18 | INSTALACIONES ELECTRICAS | milestone | 0d | 2026-07-03 | 2026-07-03 | 44 | 22d |  |  |
| 53 | 4.19 | SUMINISTRO E INSTALACION SALIDA DE ILUMINACION |  | 4d | 2026-07-04 | 2026-07-08 | 44 | 14d | 0d |  |
| 54 | 4.20 | SUMINISTRO E INSTALACION PUNTO ELECTRICO INTERRUPTOR |  | 4d | 2026-07-09 | 2026-07-13 | 53 | 14d |  |  |
| 55 | 4.21 | SUMINISTRO E INSTALACION TOMA DOBLE INCLUYE APARATO |  | 4d | 2026-07-09 | 2026-07-13 | 53 | 14d |  |  |
| 56 | 4.22 | SUMINISTRO E INSTALACION LUMINARIA LINEAL LED COMERCIAL 40 W LUZ DIA |  | 4d | 2026-07-09 | 2026-07-13 | 53 | 14d |  |  |
| 57 | 4.23 | INSTALACIONES HIDROSANITARIAS E HIDRAULICAS | milestone | 0d | 2026-06-15 | 2026-06-15 |  | 38d |  |  |
| 58 | 4.24 | SUMINISTRO E INSTALACION LAVAPLATOS SENCILLO EN ACERO INOXIDABLE |  | 6d | 2026-07-04 | 2026-07-10 | 44 | 10d | 0d |  |
| 59 | 4.25 | SUMINISTRO E INSTALACION PUNTO HIDRAULICO 1/2" |  | 6d | 2026-07-11 | 2026-07-17 | 58 | 10d |  |  |
| 60 | 4.26 | ASEO Y RETIRO DE ESCOMBROS | milestone | 0d | 2026-06-15 | 2026-06-15 |  | 38d |  |  |
| 61 | 4.27 | RETIRO DE ESCOMBROS |  | 2d | 2026-07-11 | 2026-07-13 | 58 | 12d | 0d |  |
| 62 | 4.28 | ASEO FINAL |  | 2d | 2026-07-14 | 2026-07-15 | 61 | 12d |  |  |

| ID | WBS | Task | Type | Duration | Start | Finish | Predecessors | Total slack | Free slack |
| --- | --- | --- | --- | --- | --- | --- | --- | --- | --- |
| 63 | 5 | **MODULO BAÑOS** |  | 38d | 2026-06-15 | 2026-07-29 | 7 | 0d |  |
| 64 | 5.1 | PRELIMINARES | milestone | 0d | 2026-06-15 | 2026-06-15 |  | 38d |  |
| 65 | 5.2 | LOCALIZACIÓN Y REPLANTEO |  | 1d | 2026-06-16 | 2026-06-16 |  | 0d |  |
| 66 | 5.3 | DEMOLICIÓN DE ANDÉN E > A 12 CM. (INCLUYE RETIRO Y ACARREO LIBRE HASTA 5 KM.) |  | 6d | 2026-06-17 | 2026-06-23 | 65 | 10d | 0d |
| 67 | 5.4 | EXCAVACIÓN MANUAL EN MATERIAL COMÚN |  | 6d | 2026-06-24 | 2026-06-30 | 66 | 10d | 0d |
| 68 | 5.5 | ESTRUCTURA EN CONCRETO | milestone | 0d | 2026-06-15 | 2026-06-15 |  | 38d |  |
| 69 | 5.6 | PLATINAS ENVEVIDAS DE SOPORTE PARA COLUMNAS DE ACERO |  | 4d | 2026-07-01 | 2026-07-04 | 67 | 21d |  |
| 70 | 5.7 | CONCRETO SIMPLE DE 28 Mpa. (4000 PSI) |  | 6d | 2026-07-01 | 2026-07-07 | 67 | 10d | 0d |
| 71 | 5.8 | RELLENO EN RECEBO COMPACTADO B200 |  | 4d | 2026-07-08 | 2026-07-11 | 70 | 10d | 0d |
| 72 | 5.9 | POCETA EN LADRILLO Y ENCHAPE DE 0.6 m * 0.4 m |  | 5d | 2026-07-13 | 2026-07-17 | 71 | 10d |  |
| 73 | 5.10 | ESTRUCTURA METALICA | milestone | 0d | 2026-06-15 | 2026-06-15 |  | 38d |  |
| 74 | 5.11 | SUMINISTRO, TRANSPORTE, FABRICACIÓN, FIGURADA Y/O ROLADO, ENSAMBLAJE Y MONTAJE MANUAL DE ESTRUCTURA METALICA INCLUYE PEDESTAL |  | 15d | 2026-06-17 | 2026-07-03 | 65 | 0d |  |
| 75 | 5.12 | SUMINISTRO E INSTALACIÓN DE ESMALTE SINTÉTICO PARA ESTRUCTURA METALICA. (INCLUYE BASE EN ANTICORROSIVO). |  | 6d | 2026-07-04 | 2026-07-10 | 74 | 0d |  |
| 76 | 5.13 | SUMINISTRO E INSTALACION CUBIERTA EN PERFILERIA METALICA, TEJA UPVC COLOR SEGÚN DISEÑO |  | 6d | 2026-07-11 | 2026-07-17 | 75 | 0d |  |
| 77 | 5.14 | SUMINISTRO E INSTALACION DE CANAL EN LAMINA COLD ROLLED CAL. 20 D=0.75 CON PINTURA Y ANTICORROSIVO |  | 4d | 2026-07-18 | 2026-07-22 | 76 | 0d |  |
| 78 | 5.15 | SUMINISTRO E INSTALACION LAMINA EN SUPERBOARD DE 10 MM |  | 6d | 2026-07-23 | 2026-07-29 | 77 | 0d |  |
| 79 | 5.16 | SUMINISTRO E INSTALACION PISO CERÁMICA BLANCO 50X50 |  | 5d | 2026-07-23 | 2026-07-28 | 77 | 1d |  |
| 80 | 5.17 | REJILLA DE VENTILACION 20X50 CM |  | 2d | 2026-07-23 | 2026-07-24 | 77 | 4d |  |
| 81 | 5.18 | Camerino individual para cambio de ropa, con estructura metálica, puerta metálica con cerradura, banco interior y accesorios. Incluye materiales, mano de obra 1.20*1.20 m |  | 6d | 2026-07-04 | 2026-07-10 | 74 | 16d |  |
| 82 | 5.19 | INSTALACIONES ELECTRICAS | milestone | 0d | 2026-06-15 | 2026-06-15 |  | 38d |  |
| 83 | 5.20 | SUMINISTRO E INSTALACION SALIDA DE ILUMINACION |  | 2d | 2026-07-04 | 2026-07-06 | 74 | 18d | 0d |
| 84 | 5.21 | SUMINISTRO E INSTALACION PUNTO ELECTRICO INTERRUPTOR |  | 2d | 2026-07-07 | 2026-07-08 | 83 | 18d |  |
| 85 | 5.22 | SUMINISTRO E INSTALACION TOMA DOBLE INCLUYE APARATO |  | 2d | 2026-07-07 | 2026-07-08 | 83 | 18d |  |
| 86 | 5.23 | SUMINISTRO E INSTALACION LUMINARIA LINEAL LED COMERCIAL 40 W LUZ DIA |  | 2d | 2026-07-07 | 2026-07-08 | 83 | 18d |  |
| 87 | 5.24 | INSTALACIONES HIDROSANITARIAS E HIDRAULICAS | milestone | 0d | 2026-06-15 | 2026-06-15 |  | 38d |  |
| 88 | 5.25 | SUMINISTRO E INSTALACION DE SANITARIO AHORRADOR CON ACOPLE |  | 2d | 2026-07-04 | 2026-07-06 | 74 | 14d | 0d |
| 89 | 5.26 | SUMINISTRO E INSTALACIÓN DE ORINAL INFANTIL LINEA INSTITUCIONAL. (INCLUYE ACCESORIOS) |  | 2d | 2026-07-07 | 2026-07-08 | 88 | 16d | 0d |
| 90 | 5.27 | SUMINISTRO E INSTALACION DE INCRUSTACIONES Y ESPEJO PARA BAÑO |  | 2d | 2026-07-09 | 2026-07-10 | 89 | 16d |  |
| 91 | 5.28 | SUMINISTRO E INSTALACION PUNTO HIDRAULICO 1/2" |  | 6d | 2026-07-07 | 2026-07-13 | 74, 88 | 14d |  |
| 92 | 5.29 | SUMINISTRO E INSTALACION LAVAMANOS SENCILLO CON ACOPLE |  | 2d | 2026-07-07 | 2026-07-08 | 88 | 18d |  |
| 93 | 5.30 | ASEO Y RETIRO DE ESCOMBROS | milestone | 0d | 2026-06-15 | 2026-06-15 |  | 38d |  |
| 94 | 5.31 | RETIRO DE ESCOMBROS |  | 2d | 2026-07-07 | 2026-07-08 | 88 | 17d | 0d |
| 95 | 5.32 | ASEO FINAL |  | 2d | 2026-07-08 | 2026-07-09 | 94FS-1d | 17d |  |
| 96 | 6 | FIN | milestone | 0d | 2026-03-02 | 2026-03-02 | 1 | 38d |  |
